# Master Schedule_4_04

Schedule from MS Project, 2006-01-01 to 2006-12-31, A marks actual dates.
SAIC

## Calendars

- Standard: Mon-Sun 08:00-12:00, 13:00-17:00.

## Resources

| Resource |
| --- |
| Tan |
| Fu |
| Pfarr |
| Lim |
| Saleous |
| Liang |
| Read |
| Warman |
| Woreta |
| Teague |
| DeShong |
| Broder |
| Ridgway |
| Kuyper |
| Shiles |
| Ingest Tech |
| Do |
| McMillan |
| Ye |
| Devine |
| Sinno |
| Horrocks |
| AD Manager |
| User Support |
| Hucek |
| Vogel |
| Fireman |
| LDOPE |
| Parquet |
| Ederer |
| Davidson |
| Shi |
| Christopher-Knight |
| Isaacman |
| Seaton |
| SAIC |
| GDAAC |
| LDDOPE |

## Schedule

| ID | WBS | Task | Duration | Start | Finish | Predecessors | Complete | Remaining | Baseline start | Baseline finish | Baseline duration | Total slack | Free slack | Constraint | Resources | Work | Actual work |
| --- | --- | --- | --- | --- | --- | --- | --- | --- | --- | --- | --- | --- | --- | --- | --- | --- | --- |
| 1 | 1 | **Other Projects** | 364d? | 2006-01-01 A | 2006-12-30 |  | 19% | 294.37d? | 2006-01-01 | 2006-09-30 | 273d? | 1d |  |  |  | 40345.6h | 7606.35h |
| 2 | 1.1 | **MODIS SSTG (A) (Davidson)** | 364d | 2006-01-01 A | 2006-12-30 |  | 28% | 263.24d | 2006-01-01 | 2006-09-30 | 273d | 1d |  |  |  | 4622h | 1639.79h |
| 3 | 1.1.1 | **Land (A.1)** | 364d | 2006-01-01 A | 2006-12-30 |  | 21% | 288.49d | 2006-01-01 | 2006-08-30 | 242d | 1d |  |  |  | 2580h | 864.96h |
| 4 | 1.1.1.1 | QA Phase-over (A.1.1) | 90d | 2006-01-01 A | 2006-03-31 |  | 80% | 18d | 2006-01-01 | 2006-03-31 | 90d | 35d | 0d | start no earlier than 2006-01-01 | Fireman [60%]; Davidson [75%] | 972h | 777.6h |
| 5 | 1.1.1.2 | Land SSTG (A.1.2) | 244d | 2006-04-01 | 2006-11-30 | 4 |  |  | 2006-04-01 | 2006-08-30 | 152d | 35d |  |  | Davidson [50%]; Fireman [10%] | 1171.2h |  |
| 6 | 1.1.1.3 | Land SDDT (A.1.3) | 364d | 2006-01-01 A | 2006-12-30 |  | 20% | 291.2d | 2006-01-01 | 2006-12-30 | 364d | 5d |  | start no earlier than 2006-01-01 | Saleous [5%]; Teague [5%]; Davidson [5%] | 436.8h | 87.36h |
| 7 | 1.1.2 | **Atmospheres (A.2)** | 181d | 2006-01-01 A | 2006-06-30 |  | 35% | 118d | 2006-01-01 | 2006-06-30 | 181d | 184d |  |  |  | 1011.6h | 478.8h |
| 8 | 1.1.2.1 | User Support Phase-over (A.2.1) | 91d | 2006-04-01 | 2006-06-30 | 9 |  |  | 2006-04-01 | 2006-06-30 | 91d | 195d |  |  | Hucek [45%] | 327.6h |  |
| 9 | 1.1.2.2 | Atmospheres SSTG (A.2.2) | 90d | 2006-01-01 A | 2006-03-31 |  | 70% | 27d | 2006-01-01 | 2006-03-31 | 90d | 195d | 0d | start no earlier than 2006-01-01 | Hucek [95%] | 684h | 478.8h |
| 10 | 1.1.3 | Oceans (A.3) | 90d | 2006-01-01 A | 2006-03-31 |  | 80% | 18d | 2006-01-01 | 2006-03-31 | 90d | 279d |  | start no earlier than 2006-01-01 | Fireman [5%] | 36h | 28.8h |
| 11 | 1.1.4 | Loader Module (A.4) | 212d | 2006-01-01 A | 2006-07-31 |  | 35% | 137.8d | 2006-01-01 | 2006-07-31 | 212d | 157d |  | start no earlier than 2006-01-01 | Shi [20%] | 339.2h | 118.72h |
| 12 | 1.1.5 | Troubleshooting (A.5) | 364d | 2006-01-01 A | 2006-12-30 |  | 20% | 291.2d | 2006-01-01 | 2006-12-30 | 364d | 5d |  | start no earlier than 2006-01-01 | Davidson [10%]; Hucek [5%] | 436.8h | 87.36h |
| 13 | 1.1.6 | ESDT Updates (A.6) | 273d | 2006-01-01 A | 2006-09-30 |  | 28% | 196.56d | 2006-01-01 | 2006-09-30 | 273d | 96d |  | start no earlier than 2006-01-01 | Read [10%] | 218.4h | 61.15h |
| 14 | 1.2 | **Testing (B) (Woreta)** | 364d | 2006-01-01 A | 2006-12-30 |  | 31% | 252.75d | 2006-01-01 | 2006-09-30 | 273d | 1d |  |  |  | 1980.44h | 622.61h |
| 15 | 1.2.1 | **Science Testing (B.1)** | 364d | 2006-01-01 A | 2006-12-30 |  | 28% | 260.72d | 2006-01-01 | 2006-09-30 | 273d | 1d |  |  |  | 1810.8h | 565.92h |
| 16 | 1.2.1.1 | **MODIS (B.1.1)** | 242d | 2006-01-01 A | 2006-08-30 |  | 37% | 151.3d | 2006-01-01 | 2006-08-08 | 220d | 123d |  |  |  | 1375.2h | 565.92h |
| 17 | 1.2.1.1.1 | **Atmospheres (B.1.1.1)** | 135d | 2006-01-01 A | 2006-05-15 |  | 52% | 64.8d | 2006-01-01 | 2006-05-15 | 135d | 230d |  |  |  | 396h | 224.64h |
| 18 | 1.2.1.1.1.1 | Full Staff (B.1.1.1.1) | 90d | 2006-01-01 A | 2006-03-31 |  | 78% | 19.8d | 2006-01-01 | 2006-03-31 | 90d | 233d | 0d | start no earlier than 2006-01-01 | Warman [30%]; Woreta [10%] | 288h | 224.64h |
| 19 | 1.2.1.1.1.2 | Reduced Staff (B.1.1.1.2) | 45d | 2006-04-01 | 2006-05-15 | 18 |  |  | 2006-04-01 | 2006-05-15 | 45d | 233d |  |  | Woreta [20%]; McMillan [5%]; Do [5%] | 108h |  |
| 20 | 1.2.1.1.2 | **Land (B.1.1.2)** | 242d | 2006-01-01 A | 2006-08-30 |  | 29% | 170.9d | 2006-01-01 | 2006-08-08 | 220d | 123d |  |  |  | 979.2h | 341.28h |
| 21 | 1.2.1.1.2.1 | Full Staff (B.1.1.2.1) | 90d | 2006-01-01 A | 2006-03-31 |  | 79% | 18.9d | 2006-01-01 | 2006-03-31 | 90d | 126d | 0d | start no earlier than 2006-01-01 | Warman [45%]; Woreta [15%] | 432h | 341.28h |
| 22 | 1.2.1.1.2.2 | Reduced Staff (B.1.1.2.2) | 152d | 2006-04-01 | 2006-08-30 | 21 |  |  | 2006-04-01 | 2006-08-30 | 152d | 126d |  |  | Woreta [30%]; McMillan [8%]; Do [7%] | 547.2h |  |
| 23 | 1.2.1.2 | NPP (B.1.2) | 121d | 2006-09-01 | 2006-12-30 |  |  |  | 2006-09-01 | 2006-12-30 | 121d | 4d |  | start no earlier than 2006-09-01 | Woreta [30%]; Do [8%]; McMillan [7%] | 435.6h |  |
| 24 | 1.2.2 | **I&T (B.2)** | 364d | 2006-01-01 A | 2006-12-30 |  | 32% | 246.86d | 2006-01-01 | 2006-09-30 | 273d | 1d |  |  |  | 169.64h | 56.69h |
| 25 | 1.2.2.1 | MODIS (B.2.1) | 220d | 2006-01-01 A | 2006-08-08 |  | 34% | 145.2d | 2006-01-01 | 2006-08-08 | 220d | 148d |  | start no earlier than 2006-01-01 | McMillan [5%] | 88h | 29.92h |
| 26 | 1.2.2.2 | L1 (B.2.2) | 364d | 2006-01-01 A | 2006-12-30 |  | 20% | 291.2d | 2006-01-01 | 2006-09-30 | 273d | 4d |  | start no earlier than 2006-01-01 | McMillan [2%] | 58.24h | 11.65h |
| 27 | 1.2.2.3 | Insert Testing (B.2.3) | 90d | 2006-01-01 A | 2006-03-31 |  | 77% | 20.7d | 2006-01-01 | 2006-03-31 | 90d | 278d |  | start no earlier than 2006-01-01 | McMillan [5%] | 23.4h | 15.12h |

| ID | WBS | Task | Type | Duration | Start | Finish | Predecessors | Complete | Remaining | Baseline start | Baseline finish | Baseline duration | Total slack | Free slack | Constraint | Resources | Work | Actual work |
| --- | --- | --- | --- | --- | --- | --- | --- | --- | --- | --- | --- | --- | --- | --- | --- | --- | --- | --- |
| 28 | 1.3 | **LI © (Kuyper)** |  | 364d? | 2006-01-01 A | 2006-12-30 |  | 26% | 271.11d? | 2006-01-01 | 2006-09-30 | 273d | 1d |  |  |  | 5181.04h | 1388.43h |
| 29 | 1.3.1 | **L1A and Geolocation (C.1)** |  | 364d? | 2006-01-01 A | 2006-12-30 |  | 27% | 265.41d? | 2006-01-01 | 2006-09-30 | 273d | 1d |  |  |  | 1504h | 419.52h |
| 30 | 1.3.1.1 | **Collection 6 (C.1.1)** |  | 298d? | 2006-01-01 A | 2006-10-25 |  | 30% | 209.43d? | 2006-04-15 | 2006-12-30 | 260d | 67d |  |  |  | 921.6h | 273.92h |
| 31 | 1.3.1.1.1 | Prototype |  | 107d? | 2006-01-01 A | 2006-04-17 |  | 80% | 21.4d? | 2006-01-01 | 2006-04-17 | 107d? | 258d |  | finish no earlier than 2006-04-17 | Kuyper [40%] | 342.4h | 273.92h |
| 32 | 1.3.1.1.2 | Code Dev |  | 181d? | 2006-04-28 | 2006-10-25 |  |  |  | 2006-04-28 | 2006-10-25 | 181d? | 67d |  | finish no earlier than 2006-10-25 | Kuyper [40%] | 579.2h |  |
| 33 | 1.3.1.2 | LUT Updates (C.1.2) |  | 364d | 2006-01-01 A | 2006-12-30 |  | 25% | 273d | 2006-01-01 | 2006-12-30 | 364d | 1d |  | start no earlier than 2006-01-01 | Tan [20%] | 582.4h | 145.6h |
| 34 | 1.3.2 | **L1B (C.2)** |  | 364d | 2006-01-01 A | 2006-12-30 |  | 21% | 286.77d | 2006-01-01 | 2006-09-30 | 273d | 1d |  |  |  | 1725.04h | 454.42h |
| 35 | 1.3.2.1 | **LUT Updates (C.2.1)** |  | 364d | 2006-01-01 A | 2006-12-30 |  | 23% | 279.2d | 2006-01-01 | 2006-09-30 | 273d | 1d |  |  |  | 951.28h | 301.04h |
| 36 | 1.3.2.1.1 | C4 + C5 (C.2.1.1) |  | 212d | 2006-01-01 A | 2006-07-31 |  | 40% | 127.2d | 2006-01-01 | 2006-07-31 | 212d | 1d | 0d | start no earlier than 2006-01-01 | Tan [45%] | 708.08h | 301.04h |
| 37 | 1.3.2.1.2 | C5 (C.2.1.2) |  | 152d | 2006-08-01 | 2006-12-30 | 36 |  |  | 2006-08-01 | 2006-12-30 | 152d | 1d |  |  | Tan [20%] | 243.2h |  |
| 38 | 1.3.2.2 | **Code Changes (C.2.2)** |  | 364d | 2006-01-01 A | 2006-12-30 |  | 21% | 287.55d | 2006-02-15 | 2006-03-01 | 15d | 1d |  |  |  | 725.76h | 153.38h |
| 39 | 1.3.2.2.1 | Collection 5 |  | 180d | 2006-02-16 A | 2006-08-14 |  | 20% | 144d | 2006-02-16 | 2006-08-14 | 180d | 139d |  |  | Tan [30%] | 351.36h | 86.4h |
| 40 | 1.3.2.2.2 | Collection 6 |  | 26d | 2006-12-05 | 2006-12-30 |  |  |  | 2006-12-05 | 2006-12-30 | 26d | 1d |  | start no earlier than 2006-12-05 | Tan [40%] | 83.2h |  |
| 41 | 1.3.2.2.3 | Maintenance |  | 364d | 2006-01-01 A | 2006-12-30 |  | 23% | 280.28d | 2006-01-01 | 2006-12-30 | 364d | 1d |  | start no earlier than 2006-01-01 | Tan [10%] | 291.2h | 66.98h |
| 42 | 1.3.2.3 | L1B Tools (C.2.3) |  | 30d | 2006-05-18 | 2006-06-16 |  |  |  | 2006-05-18 | 2006-06-16 | 30d | 198d |  | start no earlier than 2006-05-18 | Tan [20%] | 48h |  |
| 43 | 1.3.3 | Control Point (C.3) |  | 29d | 2006-02-16 A | 2006-03-16 A |  | 100% |  | 2006-02-16 | 2006-03-15 | 28d |  |  |  |  |  |  |
| 44 | 1.3.4 | **Libraries (C.4)** |  | 312d | 2006-02-16 A | 2006-12-24 |  | 55% | 140.4d | 2006-03-15 | 2006-04-13 | 30d | 7d |  |  |  | 204.8h | 112.64h |
| 45 | 1.3.4.1 | SDP |  | 44d | 2006-02-16 A | 2006-03-31 |  | 80% | 8.8d | 2006-02-16 | 2006-03-31 | 44d | 275d |  |  | Kuyper [40%] | 140.8h | 112.64h |
| 46 | 1.3.4.2 | MAPI |  | 20d | 2006-12-05 | 2006-12-24 |  |  |  | 2006-12-05 | 2006-12-24 | 20d | 7d |  | start no earlier than 2006-12-05 | Kuyper [40%] | 64h |  |
| 47 | 1.3.5 | Troubleshooting (C.5) |  | 364d | 2006-01-01 A | 2006-12-30 |  | 23% | 280.28d | 2006-01-01 | 2006-12-30 | 364d | 1d |  | start no earlier than 2006-01-01 | Kuyper [60%] | 1747.2h | 401.86h |
| 48 | 1.4 | **NPP (D) (Isaacman)** |  | 364d? | 2006-01-01 A | 2006-12-30 |  | 9% | 331.27d? | 2006-01-01 | 2006-09-30 | 273d? | 1d |  |  |  | 8816.16h | 1329.36h |
| 49 | 1.4.1 | **Science Code (D.1)** |  | 364d? | 2006-01-01 A | 2006-12-30 |  | 25% | 274.17d? | 2006-01-01 | 2006-09-30 | 273d? | 1d |  |  |  | 2757.84h | 901.36h |
| 50 | 1.4.1.1 | **Prototype Chain (D.1.1)** |  | 90d? | 2006-01-01 A | 2006-03-31 |  | 74% | 23.25d? | 2006-01-01 | 2006-03-31 | 90d? | 275d |  |  |  | 1117.84h | 833.04h |
| 51 | 1.4.1.1.1 | Develop (D.1.1.1) |  | 89d | 2006-01-01 A | 2006-03-30 |  | 75% | 22.25d | 2006-01-01 | 2006-03-30 | 89d | 275d | 0d | start no earlier than 2006-01-01 | Isaacman [75%]; Davidson [25%]; Fireman [40%]; Shi [15%]; Ye [5%] | 1117.84h | 833.04h |
| 52 | 1.4.1.1.2 | Build 1 (D.1.1.2) | milestone | 1d? | 2006-03-31 | 2006-03-31 | 51 |  |  | 2006-03-31 | 2006-03-31 | 1d? | 275d |  | start no earlier than 2006-03-31 |  |  |  |
| 53 | 1.4.1.2 | Fire (D.1.2) |  | 59d | 2006-02-16 A | 2006-04-15 |  | 50% | 29.5d | 2006-02-16 | 2006-03-31 | 44d | 260d |  |  | Isaacman [15%]; Shi [5%] | 94.4h | 47.2h |

| ID | WBS | Task | Type | Duration | Start | Finish | Predecessors | Complete | Remaining | Baseline start | Baseline finish | Baseline duration | Total slack | Free slack | Constraint | Resources | Work | Actual work |
| --- | --- | --- | --- | --- | --- | --- | --- | --- | --- | --- | --- | --- | --- | --- | --- | --- | --- | --- |
| 54 | 1.4.1.3 | **Granulation (D.1.3)** |  | 60d | 2006-04-01 | 2006-05-30 |  |  |  | 2006-04-01 | 2006-05-30 | 60d | 215d |  |  |  | 144h |  |
| 55 | 1.4.1.3.1 | 750m (D.1.3.1) |  | 30d | 2006-04-01 | 2006-04-30 | 69 |  |  | 2006-04-01 | 2006-04-30 | 30d | 215d | 0d | start no earlier than 2006-04-01 | Isaacman [25%]; Shi [5%] | 72h |  |
| 56 | 1.4.1.3.2 | 375m (D.1.3.2) |  | 30d | 2006-05-01 | 2006-05-30 | 55, 70 |  |  | 2006-05-01 | 2006-05-30 | 30d | 215d |  |  | Isaacman [25%]; Shi [5%] | 72h |  |
| 57 | 1.4.1.4 | Other PGEs (D.1.4) |  | 244d | 2006-05-01 | 2006-12-30 |  |  |  | 2006-05-01 | 2006-12-30 | 244d | 1d |  | start no earlier than 2006-05-01 | Isaacman [50%]; Davidson [20%] | 1366.4h |  |
| 58 | 1.4.1.5 | Re-integration (D.1.5) |  | 44d | 2006-02-16 A | 2006-03-31 |  | 60% | 17.6d | 2006-02-16 | 2006-03-31 | 44d | 275d |  |  | Isaacman [10%] | 35.2h | 21.12h |
| 59 | 1.4.2 | **Ops Code (D.2)** |  | 333d? | 2006-02-01 | 2006-12-30 |  |  |  | 2006-02-01 | 2006-09-30 | 242d? | 1d |  |  |  | 1667.2h |  |
| 60 | 1.4.2.1 | **Wrapper (D.2.1)** |  | 333d? | 2006-02-01 | 2006-12-30 |  |  |  | 2006-02-01 | 2006-09-30 | 242d? | 1d |  |  |  | 887.2h |  |
| 61 | 1.4.2.1.1 | Cloud Mask (D.2.1.1) |  | 30d | 2006-04-01 | 2006-04-30 |  |  |  | 2006-04-01 | 2006-04-30 | 30d | 245d |  | start no earlier than 2006-04-01 | Isaacman [50%] | 120h |  |
| 62 | 1.4.2.1.2 | Drop 1.3 | milestone | 1d? | 2006-02-01 | 2006-02-01 |  |  |  | 2006-02-01 | 2006-02-01 | 1d? | 333d |  | start no earlier than 2006-02-01 |  |  |  |
| 63 | 1.4.2.1.3 | Other PGEs (D.2.1.2) |  | 274d | 2006-04-01 | 2006-12-30 |  |  |  | 2006-04-01 | 2006-12-30 | 274d | 1d |  | start no earlier than 2006-04-01 | Isaacman [25%]; Davidson [10%] | 767.2h |  |
| 64 | 1.4.2.2 | Integrate Code (D.2.2) |  | 213d | 2006-06-01 | 2006-12-30 |  |  |  | 2006-06-01 | 2006-12-30 | 213d | 1d |  | start no earlier than 2006-06-01 | Isaacman [10%]; Davidson [10%] | 340.8h |  |
| 65 | 1.4.2.3 | Chain Testing (D.2.3) |  | 183d | 2006-07-01 | 2006-12-30 |  |  |  | 2006-07-01 | 2006-12-30 | 183d | 1d |  | start no earlier than 2006-07-01 | Isaacman [10%]; Shi [15%] | 366h |  |
| 66 | 1.4.2.4 | Re-integration (D.2.4) |  | 183d | 2006-07-01 | 2006-12-30 |  |  |  | 2006-07-01 | 2006-12-30 | 183d | 1d |  | start no earlier than 2006-07-01 | Isaacman [5%] | 73.2h |  |
| 67 | 1.4.3 | **Proxy Generator (D.3)** |  | 89d | 2006-02-01 A | 2006-04-30 |  | 41% | 52.64d | 2006-02-01 | 2006-04-30 | 89d | 245d |  |  |  | 884h | 428h |
| 68 | 1.4.3.1 | **MODIS Tiling/NPP Grid (D.3.1)** |  | 74d | 2006-02-16 A | 2006-04-30 |  | 36% | 47.6d | 2006-02-16 | 2006-04-30 | 74d | 215d |  |  |  | 472h | 211.2h |
| 69 | 1.4.3.1.1 | 750m (D.3.1.1) |  | 44d | 2006-02-16 A | 2006-03-31 |  | 60% | 17.6d | 2006-02-16 | 2006-03-31 | 44d | 215d | 0d |  | Seaton | 352h | 211.2h |
| 70 | 1.4.3.1.2 | 375m (D.3.1.2) |  | 30d | 2006-04-01 | 2006-04-30 | 69 |  |  | 2006-04-01 | 2006-04-30 | 30d | 215d | 0d |  | Seaton [50%] | 120h |  |
| 71 | 1.4.3.2 | **SDR Generator (D.3.2)** |  | 89d | 2006-02-01 A | 2006-04-30 |  | 45% | 48.8d | 2006-02-01 | 2006-04-30 | 89d | 245d |  |  |  | 412h | 216.8h |
| 72 | 1.4.3.2.1 | Sci Code Input (D.3.2.1) |  | 28d | 2006-02-01 A | 2006-02-28 A |  | 100% |  | 2006-02-01 | 2006-02-28 | 28d |  |  | start no earlier than 2006-02-01 | Vogel [75%] | 168h | 168h |
| 73 | 1.4.3.2.2 | VIIRS Wavelengths (D.3.2.2) |  | 61d | 2006-03-01 A | 2006-04-30 | 72 | 20% | 48.8d | 2006-03-01 | 2006-04-30 | 61d | 245d |  |  | Vogel [50%] | 244h | 48.8h |
| 74 | 1.4.4 | **DDR Development (D.4)** |  | 274d | 2006-04-01 | 2006-12-30 |  |  |  | 2006-02-16 | 2006-09-30 | 227d? | 1d |  |  |  | 2630.32h |  |
| 75 | 1.4.4.1 | MODIS (D.4.1) |  | 122d | 2006-04-01 | 2006-07-31 |  |  |  | 2006-04-01 | 2006-07-31 | 122d | 153d |  | start no earlier than 2006-04-01 | Seaton [50%]; Shi [2%]; Vogel [25%] | 751.52h |  |
| 76 | 1.4.4.2 | LDOPE (D.4.2) |  | 153d | 2006-05-01 | 2006-09-30 |  |  |  | 2006-05-01 | 2006-09-30 | 153d | 92d |  | start no earlier than 2006-05-01 | Seaton [50%]; Shi [2%]; Vogel [25%] | 942.48h |  |
| 77 | 1.4.4.3 | NICSE (D.4.3) |  | 152d | 2006-08-01 | 2006-12-30 |  |  |  | 2006-08-01 | 2006-12-30 | 152d | 1d |  | start no earlier than 2006-08-01 | Seaton [50%]; Shi [2%]; Vogel [25%] | 936.32h |  |
| 78 | 1.4.5 | LDOPE Tools Dev (D.5) |  | 274d | 2006-04-01 | 2006-12-30 |  |  |  | 2006-02-16 | 2006-02-16 | 1d? | 1d |  | start no earlier than 2006-04-01 | LDOPE [40%] | 876.8h |  |

| ID | WBS | Task | Type | Duration | Start | Finish | Predecessors | Complete | Remaining | Baseline start | Baseline finish | Baseline duration | Total slack | Free slack | Constraint | Resources | Work | Actual work |
| --- | --- | --- | --- | --- | --- | --- | --- | --- | --- | --- | --- | --- | --- | --- | --- | --- | --- | --- |
| 79 | 1.4.6 | **Operations (D.6)** |  | 44d? | 2006-02-16 A | 2006-03-31 |  | 48% | 22.69d? | 2006-02-16 | 2006-03-31 | 44d? | 275d |  |  |  |  |  |
| 80 | 1.4.6.1 | Quality Assurance (D.6.1) |  | 1d? | 2006-02-16 | 2006-02-16 |  |  |  | 2006-02-16 | 2006-02-16 | 1d? | 318d |  |  |  |  |  |
| 81 | 1.4.6.2 | **Data Ingest Test (D.6.2)** |  | 31d | 2006-03-01 A | 2006-03-31 |  | 50% | 15.5d | 2006-03-01 | 2006-03-31 | 31d | 275d |  |  |  |  |  |
| 82 | 1.4.6.2.1 | FTP from SD3E (D.6.2.1) |  | 31d | 2006-03-01 A | 2006-03-31 |  | 50% | 15.5d | 2006-03-01 | 2006-03-31 | 31d | 275d |  | start no earlier than 2006-03-01 |  |  |  |
| 83 | 1.5 | **Access Dev (E) (Ederer)** |  | 318d? | 2006-02-16 A | 2006-12-30 |  | 6% | 299.49d? | 2006-02-16 | 2006-09-30 | 227d? | 1d |  |  |  | 2699.2h | 40.8h |
| 84 | 1.5.1 | **Core System (E.2)** |  | 318d? | 2006-02-16 A | 2006-12-30 |  | 6% | 299.14d? | 2006-02-16 | 2006-09-30 | 227d? | 1d |  |  |  | 2699.2h | 40.8h |
| 85 | 1.5.1.1 | Requirements (E.2.1) |  | 30d | 2006-02-16 A | 2006-03-17 |  | 85% | 4.5d | 2006-02-16 | 2006-03-17 | 30d | 289d |  |  | Ederer [20%] | 48h | 40.8h |
| 86 | 1.5.1.2 | **Beta System (E.2.2)** |  | 291d? | 2006-03-15 | 2006-12-30 |  |  |  | 2006-03-15 | 2006-09-30 | 200d? | 1d |  |  |  | 1709.6h |  |
| 87 | 1.5.1.2.1 | Develop (E.2.2.1) |  | 120d | 2006-03-15 | 2006-07-12 |  |  |  | 2006-03-15 | 2006-07-12 | 120d | 1d | 0d | start no earlier than 2006-03-15 | Ederer [80%]; Horrocks [35%] | 1104h |  |
| 88 | 1.5.1.2.2 | Test (E.2.2.2) |  | 64d | 2006-07-13 | 2006-09-14 | 87 |  |  | 2006-07-13 | 2006-09-14 | 64d | 1d | 0d |  | Ederer [80%]; Horrocks [25%]; Sinno [5%] | 563.2h |  |
| 89 | 1.5.1.2.3 | Deploy (E.2.2.3) | milestone | 1d? | 2006-09-15 | 2006-09-15 | 88 |  |  | 2006-09-15 | 2006-09-15 | 1d? | 1d | 0d | start no earlier than 2006-09-15 |  |  |  |
| 90 | 1.5.1.2.4 | External Test (E.2.2.4) |  | 106d | 2006-09-16 | 2006-12-30 | 89 |  |  | 2006-09-16 | 2006-12-30 | 106d | 1d |  | start no earlier than 2006-09-16 | Ederer [5%] | 42.4h |  |
| 91 | 1.5.1.3 | **Production System (E.2.3)** |  | 318d? | 2006-02-16 | 2006-12-30 |  |  |  | 2006-02-16 | 2006-02-16 | 1d? | 1d |  |  |  | 941.6h |  |
| 92 | 1.5.1.3.1 | Develop (E.2.3.1) |  | 107d | 2006-09-15 | 2006-12-30 | 88 |  |  | 2006-09-15 | 2006-12-30 | 107d | 1d |  | start no earlier than 2006-09-15 | Horrocks [25%]; Ederer [85%] | 941.6h |  |
| 93 | 1.5.1.3.2 | Test (E.2.3.2) |  | 1d? | 2006-02-16 | 2006-02-16 |  |  |  | 2006-02-16 | 2006-02-16 | 1d? | 318d |  |  |  |  |  |
| 94 | 1.5.1.3.3 | Deploy (E.2.3.3) |  | 1d? | 2006-02-16 | 2006-02-16 |  |  |  | 2006-02-16 | 2006-02-16 | 1d? | 318d |  | start no earlier than 2006-02-16 |  |  |  |
| 95 | 1.5.2 | **Full System (E.3)** |  | 1d? | 2006-02-16 | 2006-02-16 |  |  |  | 2006-02-16 | 2006-02-16 | 1d? | 318d |  |  |  |  |  |
| 96 | 1.5.2.1 | Requirements (E.3.1) |  | 1d? | 2006-02-16 | 2006-02-16 |  |  |  | 2006-02-16 | 2006-02-16 | 1d? | 318d |  |  |  |  |  |
| 97 | 1.5.2.2 | **Beta System (E.3.2)** |  | 1d? | 2006-02-16 | 2006-02-16 |  |  |  | 2006-02-16 | 2006-02-16 | 1d? | 318d |  |  |  |  |  |
| 98 | 1.5.2.2.1 | Develop (E.3.2.1) |  | 1d? | 2006-02-16 | 2006-02-16 |  |  |  | 2006-02-16 | 2006-02-16 | 1d? | 318d |  |  |  |  |  |
| 99 | 1.5.2.2.2 | Test (E.3.2.2) |  | 1d? | 2006-02-16 | 2006-02-16 |  |  |  | 2006-02-16 | 2006-02-16 | 1d? | 318d |  |  |  |  |  |
| 100 | 1.5.2.2.3 | Deploy (E.3.2.3) |  | 1d? | 2006-02-16 | 2006-02-16 |  |  |  | 2006-02-16 | 2006-02-16 | 1d? | 318d |  |  |  |  |  |
| 101 | 1.5.2.2.4 | External Test (E.3.2.4) |  | 1d? | 2006-02-16 | 2006-02-16 |  |  |  | 2006-02-16 | 2006-02-16 | 1d? | 318d |  |  |  |  |  |
| 102 | 1.5.2.3 | **Production System (E.3.3)** |  | 1d? | 2006-02-16 | 2006-02-16 |  |  |  | 2006-02-16 | 2006-02-16 | 1d? | 318d |  |  |  |  |  |
| 103 | 1.5.2.3.1 | Develop (E.3.3.1) |  | 1d? | 2006-02-16 | 2006-02-16 |  |  |  | 2006-02-16 | 2006-02-16 | 1d? | 318d |  |  |  |  |  |
| 104 | 1.5.2.3.2 | Test (E.3.3.2) |  | 1d? | 2006-02-16 | 2006-02-16 |  |  |  | 2006-02-16 | 2006-02-16 | 1d? | 318d |  |  |  |  |  |
| 105 | 1.5.2.3.3 | Deploy (E.3.3.3) |  | 1d? | 2006-02-16 | 2006-02-16 |  |  |  | 2006-02-16 | 2006-02-16 | 1d? | 318d |  |  |  |  |  |

| ID | WBS | Task | Duration | Start | Finish | Predecessors | Complete | Remaining | Baseline start | Baseline finish | Baseline duration | Total slack | Free slack | Constraint | Resources | Work | Actual work |
| --- | --- | --- | --- | --- | --- | --- | --- | --- | --- | --- | --- | --- | --- | --- | --- | --- | --- |
| 106 | 1.6 | **AVHRR/Landsat (F) (Saleous)** | 364d | 2006-01-01 A | 2006-12-30 |  | 16% | 304.92d | 2006-01-01 | 2006-09-30 | 273d | 1d |  |  |  | 10221.6h | 1287.66h |
| 107 | 1.6.1 | **AVHRR/MODIS REASoN (F.1)** | 364d | 2006-01-01 A | 2006-12-30 |  | 19% | 296.5d | 2006-01-01 | 2006-09-30 | 273d | 1d |  |  |  | 4504h | 534.6h |
| 108 | 1.6.1.1 | Reduced Staff (F.1.1) | 90d | 2006-01-01 A | 2006-03-31 |  | 75% | 22.5d | 2006-01-01 | 2006-03-31 | 90d | 1d | 0d | start no earlier than 2006-01-01 | Pfarr [25%]; Lim [50%]; Liang [15%]; Saleous [45%] | 777.6h | 534.6h |
| 109 | 1.6.1.2 | Full Staff (F.1.2) | 274d | 2006-04-01 | 2006-12-30 | 108 |  |  | 2006-04-01 | 2006-12-30 | 274d | 1d |  |  | Pfarr [25%]; Lim [50%]; Liang [50%]; Saleous [45%] | 3726.4h |  |
| 110 | 1.6.2 | **LEDAPS (F.2)** | 364d | 2006-01-01 A | 2006-12-30 |  | 15% | 310d | 2006-01-01 | 2006-12-30 | 364d | 1d |  |  |  | 4116h | 496.8h |
| 111 | 1.6.2.1 | Reduced Staff (F.2.1) | 90d | 2006-01-01 A | 2006-03-31 |  | 60% | 36d | 2006-01-01 | 2006-03-31 | 90d | 1d | 0d | start no earlier than 2006-01-01 | Pfarr [25%]; Lim [50%]; Saleous [25%]; Liang [15%] | 828h | 496.8h |
| 112 | 1.6.2.2 | Full Staff (F.2.2) | 274d | 2006-04-01 | 2006-12-30 | 111 |  |  | 2006-04-01 | 2006-12-30 | 274d | 1d |  |  | Pfarr [25%]; Lim [50%]; Liang [50%]; Saleous [25%] | 3288h |  |
| 113 | 1.6.3 | LDOPE (F.3) | 364d | 2006-01-01 A | 2006-12-30 |  | 16% | 305.76d | 2006-01-01 | 2006-12-30 | 364d | 1d |  | start no earlier than 2006-01-01 | Pfarr [20%] | 582.4h | 93.18h |
| 114 | 1.6.4 | UMD-NPP (F.4) | 364d | 2006-01-01 A | 2006-12-30 |  | 16% | 305.76d | 2006-01-01 | 2006-12-30 | 364d | 1d |  | start no earlier than 2006-01-01 | Saleous [15%] | 436.8h | 69.89h |
| 115 | 1.6.5 | UMD-MODIS SR (F.5) | 364d | 2006-01-01 A | 2006-12-30 |  | 16% | 305.76d | 2006-01-01 | 2006-12-30 | 364d | 1d |  | start no earlier than 2006-01-01 | Saleous [10%] | 291.2h | 46.59h |
| 116 | 1.6.6 | UMD-Fire/Emission (F.6) | 364d | 2006-01-01 A | 2006-12-30 |  | 16% | 305.76d | 2006-01-01 | 2006-12-30 | 364d | 1d |  | start no earlier than 2006-01-01 | Saleous [10%] | 291.2h | 46.59h |
| 117 | 1.7 | Program Management (G) (Teague) | 364d | 2006-01-01 A | 2006-12-30 |  | 26% | 269.36d | 2006-01-01 | 2006-12-30 | 364d | 1d |  | start no earlier than 2006-01-01 | Teague [10%]; Pfarr [15%] | 728h | 189.28h |
| 118 | 1.8 | **Documentation (H) (Read)** | 364d | 2006-01-01 A | 2006-12-30 |  | 18% | 300.11d | 2006-01-01 | 2006-09-30 | 273d | 1d |  |  |  | 1896.72h | 298.26h |
| 119 | 1.8.1 | **NPP Documentation (H.1)** | 364d | 2006-01-01 A | 2006-12-30 |  | 16% | 305.76d | 2006-01-01 | 2006-09-30 | 273d | 1d |  |  |  | 1718.08h | 274.89h |
| 120 | 1.8.1.1 | System Descr Doc (H.1.1) | 364d | 2006-01-01 A | 2006-12-30 |  | 16% | 305.76d | 2006-01-01 | 2006-12-30 | 364d | 1d |  | start no earlier than 2006-01-01 | Read [20%] | 582.4h | 93.18h |
| 121 | 1.8.1.2 | System Design Doc (H.1.2) | 364d | 2006-01-01 A | 2006-12-30 |  | 16% | 305.76d | 2006-01-01 | 2006-12-30 | 364d | 1d |  | start no earlier than 2006-01-01 | Read [2%] | 58.24h | 9.32h |
| 122 | 1.8.1.3 | Doc Research (H.1.3) | 364d | 2006-01-01 A | 2006-12-30 |  | 16% | 305.76d | 2006-01-01 | 2006-12-30 | 364d | 1d |  | start no earlier than 2006-01-01 | Read [30%] | 873.6h | 139.78h |
| 123 | 1.8.1.4 | PGE Dependency (H.1.4) | 364d | 2006-01-01 A | 2006-12-30 |  | 16% | 305.76d | 2006-01-01 | 2006-12-30 | 364d | 1d |  | start no earlier than 2006-01-01 | Read [2%] | 58.24h | 9.32h |
| 124 | 1.8.1.5 | Volumes and Loads (H.1.5) | 364d | 2006-01-01 A | 2006-12-30 |  | 16% | 305.76d | 2006-01-01 | 2006-12-30 | 364d | 1d |  | start no earlier than 2006-01-01 | Read [5%] | 145.6h | 23.3h |
| 125 | 1.8.2 | **Access Documentation (H.2)** | 62d | 2006-10-01 | 2006-12-01 |  |  |  | 2006-10-01 | 2006-12-01 | 62d | 30d |  |  |  | 69.44h |  |
| 126 | 1.8.2.1 | NACP User Guide (H.2.1) | 62d | 2006-10-01 | 2006-12-01 |  |  |  | 2006-10-01 | 2006-12-01 | 62d | 30d |  | start no earlier than 2006-10-01 | Read [14%] | 69.44h |  |
| 127 | 1.8.3 | **MODIS Documentation (H.3)** | 273d | 2006-01-01 A | 2006-09-30 |  | 22% | 212.03d | 2006-01-01 | 2006-09-30 | 273d | 92d |  |  |  | 109.2h | 23.37h |
| 128 | 1.8.3.1 | System Desc Doc (H.3.1) | 273d | 2006-01-01 A | 2006-09-30 |  | 25% | 204.75d | 2006-01-01 | 2006-09-30 | 273d | 92d |  | start no earlier than 2006-01-01 | Read [1%] | 21.84h | 5.46h |
| 129 | 1.8.3.2 | PGE Dependency (H.3.2) | 273d | 2006-01-01 A | 2006-09-30 |  | 22% | 212.94d | 2006-01-01 | 2006-09-30 | 273d | 92d |  | start no earlier than 2006-01-01 | Read [1%] | 21.84h | 4.8h |
| 130 | 1.8.3.3 | Volumes and Loads (H.3.3) | 273d | 2006-01-01 A | 2006-09-30 |  | 20% | 218.4d | 2006-01-01 | 2006-09-30 | 273d | 92d |  | start no earlier than 2006-01-01 | Read [3%] | 65.52h | 13.1h |

| ID | WBS | Task | Type | Duration | Start | Finish | Predecessors | Complete | Remaining | Baseline start | Baseline finish | Baseline duration | Total slack | Free slack | Constraint | Resources | Work | Actual work |
| --- | --- | --- | --- | --- | --- | --- | --- | --- | --- | --- | --- | --- | --- | --- | --- | --- | --- | --- |
| 131 | 1.9 | **CM (I) (Christopher-Knight)** |  | 364d | 2006-01-01 A | 2006-12-30 |  | 15% | 311.16d | 2006-01-01 | 2006-09-30 | 273d? | 1d |  |  |  | 1080h | 230.4h |
| 132 | 1.9.1 | NPP (I.1) |  | 274d | 2006-04-01 | 2006-12-30 |  |  |  | 2006-04-01 | 2006-09-30 | 183d | 1d |  | start no earlier than 2006-04-01 | Christopher-Knight [10%] | 219.2h |  |
| 133 | 1.9.2 | Access (I.2) |  | 274d | 2006-04-01 | 2006-12-30 |  |  |  | 2006-04-01 | 2006-09-30 | 183d | 1d |  | start no earlier than 2006-04-01 | Christopher-Knight [5%] | 109.6h |  |
| 134 | 1.9.3 | **L1 (I.3)** |  | 364d | 2006-01-01 A | 2006-12-30 |  | 20% | 292d | 2006-01-01 | 2006-09-30 | 273d | 1d |  |  |  | 145.6h | 28.8h |
| 135 | 1.9.3.1 | Reduced Staff (1.3.1) |  | 90d | 2006-01-01 A | 2006-03-31 |  | 80% | 18d | 2006-01-01 | 2006-03-31 | 90d | 1d | 0d | start no earlier than 2006-01-01 | Liang [5%] | 36h | 28.8h |
| 136 | 1.9.3.2 | Full Staff (1.3.2) |  | 274d | 2006-04-01 | 2006-12-30 | 135 |  |  | 2006-04-01 | 2006-12-30 | 274d | 1d |  |  | Christopher-Knight [5%] | 109.6h |  |
| 137 | 1.9.4 | **MODIS (I.4)** |  | 364d | 2006-01-01 A | 2006-12-30 |  | 25% | 273d | 2006-01-01 | 2006-09-30 | 273d? | 1d |  |  |  | 605.6h | 201.6h |
| 138 | 1.9.4.1 | **PGE Support (!.4.1)** |  | 212d | 2006-01-01 A | 2006-07-31 |  | 34% | 140d | 2006-01-01 | 2006-07-31 | 212d | 153d |  |  |  | 460h | 172.8h |
| 139 | 1.9.4.1.1 | Reduced Staff (1.4.1.1) |  | 90d | 2006-01-01 A | 2006-03-31 |  | 80% | 18d | 2006-01-01 | 2006-03-31 | 90d | 153d | 0d | start no earlier than 2006-01-01 | Liang [30%] | 216h | 172.8h |
| 140 | 1.9.4.1.2 | Full Staff (1.4.1.2) |  | 122d | 2006-04-01 | 2006-07-31 | 139 |  |  | 2006-04-01 | 2006-07-31 | 122d | 153d |  |  | Christopher-Knight [25%] | 244h |  |
| 141 | 1.9.4.2 | **DAP Delivery (I.4.2)** |  | 364d | 2006-01-01 A | 2006-12-30 |  | 20% | 292d | 2006-01-01 | 2006-09-30 | 273d? | 1d |  |  |  | 145.6h | 28.8h |
| 142 | 1.9.4.2.1 | Reduced Staff (1.4.2.1) |  | 90d | 2006-01-01 A | 2006-03-31 |  | 80% | 18d | 2006-01-01 | 2006-03-31 | 90d | 1d | 0d | start no earlier than 2006-01-01 | Liang [5%] | 36h | 28.8h |
| 143 | 1.9.4.2.2 | Full Staff (1.4.2.2) |  | 274d | 2006-04-01 | 2006-12-30 | 142 |  |  | 2006-04-01 | 2006-12-30 | 274d | 1d |  |  | Christopher-Knight [5%] | 109.6h |  |
| 144 | 1.10 | **SD3E (J) (Fu)** |  | 364d? | 2006-01-01 A | 2006-12-30 |  | 20% | 292.8d? | 2006-01-01 | 2006-09-29 | 272d? | 1d |  |  |  | 1452h | 284.8h |
| 145 | 1.10.1 | Develop Build 1 (J.1) |  | 89d | 2006-01-01 A | 2006-03-30 |  | 80% | 17.8d | 2006-01-01 | 2006-03-30 | 89d | 1d | 0d | start no earlier than 2006-01-01 | Fu [50%] | 356h | 284.8h |
| 146 | 1.10.2 | Deliver Build 1 (J.2) | milestone | 1d? | 2006-03-31 | 2006-03-31 | 145 |  |  | 2006-03-31 | 2006-03-31 | 1d? | 1d | 0d |  |  |  |  |
| 147 | 1.10.3 | Develop Build 2 (J.3) |  | 274d | 2006-04-01 | 2006-12-30 | 146 |  |  | 2006-04-01 | 2006-09-29 | 182d | 1d |  |  | Fu [50%] | 1096h |  |
| 148 | 1.11 | **NPPDAPS (K) (Ye)** |  | 334d? | 2006-01-01 A | 2006-11-30 |  | 24% | 254.42d? | 2006-01-01 | 2006-09-30 | 273d? | 31d |  |  |  | 1668.4h | 294.96h |
| 149 | 1.11.1 | **Build 1 (K.1)** |  | 105d? | 2006-01-01 A | 2006-04-15 |  | 70% | 31.31d? | 2006-01-01 | 2006-04-15 | 105d? | 260d |  |  |  | 378h | 294.96h |
| 150 | 1.11.1.1 | Requirements (K.1.1) |  | 21d | 2006-01-01 A | 2006-01-21 A |  | 100% |  | 2006-01-01 | 2006-01-21 | 21d |  |  | start no earlier than 2006-01-01 | Teague [20%] | 33.6h | 33.6h |
| 151 | 1.11.1.2 | Develop (K.1.2) |  | 52d | 2006-01-22 A | 2006-03-14 A | 150 | 100% |  | 2006-01-22 | 2006-03-20 | 58d |  |  |  | Fu [40%]; Ye [10%]; Shi [10%] | 249.6h | 249.6h |
| 152 | 1.11.1.3 | Testing (K.1.3) |  | 21d | 2006-03-10 A | 2006-03-30 |  | 20% | 16.8d | 2006-03-10 | 2006-03-30 | 21d | 276d |  | start no earlier than 2006-03-10 | Fu [10%]; Ye [25%] | 58.8h | 11.76h |
| 153 | 1.11.1.4 | Deliver (K.1.4) | milestone | 1d? | 2006-03-31 | 2006-03-31 |  |  |  | 2006-03-31 | 2006-03-31 | 1d? | 275d |  | start no earlier than 2006-03-31 |  |  |  |
| 154 | 1.11.1.5 | Documentation (K.1..5) |  | 15d | 2006-04-01 | 2006-04-15 |  |  |  | 2006-04-01 | 2006-04-15 | 15d | 260d |  | start no earlier than 2006-04-01 | Fu [30%] | 36h |  |

| ID | WBS | Task | Type | Duration | Start | Finish | Predecessors | Complete | Remaining | Baseline start | Baseline finish | Baseline duration | Total slack | Free slack | Constraint | Resources | Work | Actual work |
| --- | --- | --- | --- | --- | --- | --- | --- | --- | --- | --- | --- | --- | --- | --- | --- | --- | --- | --- |
| 155 | 1.11.2 | **Build 2 (K.2)** |  | 214d? | 2006-05-01 | 2006-11-30 |  |  |  | 2006-02-16 | 2006-09-30 | 227d? | 31d |  |  |  | 1290.4h |  |
| 156 | 1.11.2.1 | Requirements (K.2.1) |  | 31d | 2006-05-01 | 2006-05-31 |  |  |  | 2006-05-01 | 2006-05-31 | 31d | 82d | 0d | start no earlier than 2006-05-01 | Teague [10%] | 24.8h |  |
| 157 | 1.11.2.2 | Development (K.2.2) |  | 132d | 2006-06-01 | 2006-10-10 | 156 |  |  | 2006-06-01 | 2006-10-10 | 132d | 82d |  | start no earlier than 2006-06-01 | Devine [30%]; Ye [20%]; Fu [30%]; Shi [30%] | 1161.6h |  |
| 158 | 1.11.2.3 | Testing (K.2.3) |  | 20d | 2006-10-01 | 2006-10-20 |  |  |  | 2006-10-01 | 2006-10-20 | 20d | 72d |  | start no earlier than 2006-10-01 | Ye [10%]; Fu [10%] | 32h |  |
| 159 | 1.11.2.4 | Deliver (K.2.4) | milestone | 1d? | 2006-11-01 | 2006-11-01 |  |  |  | 2006-11-01 | 2006-11-01 | 1d? | 60d |  | start no earlier than 2006-11-01 |  |  |  |
| 160 | 1.11.2.5 | Documentation (K.2.5) |  | 30d | 2006-11-01 | 2006-11-30 |  |  |  | 2006-11-01 | 2006-11-30 | 30d | 31d |  | start no earlier than 2006-11-01 | Fu [30%] | 72h |  |
| 161 | 2 | **MODAPS Augmentation** |  | 365d? | 2006-01-01 A | 2006-12-31 |  | 18% | 300.88d? | 2006-01-01 | 2006-12-10 | 344d? | 0d |  |  |  | 47200.6h | 8023.31h |
| 162 | 2.1 | **Reviews (1.1) (Teague)** |  | 273d | 2006-01-01 A | 2006-09-30 |  | 38% | 170.03d | 2006-01-01 | 2006-09-30 | 273d | 92d |  |  |  | 271.6h | 174.4h |
| 163 | 2.1.1 | IPR (1.1.1) |  | 7d | 2006-02-21 A | 2006-02-27 A |  | 100% |  | 2006-02-21 | 2006-02-27 | 7d |  |  | start no earlier than 2006-02-21 | Teague [20%] | 11.2h | 11.2h |
| 164 | 2.1.2 | Monthly ESDIS Reviews (1.1.2) |  | 119d | 2006-04-04 | 2006-07-31 |  |  |  | 2006-04-01 | 2006-07-31 | 122d | 153d |  | start no earlier than 2006-04-04 | Teague [5%] | 47.6h |  |
| 165 | 2.1.3 | ORR (1.1.3) |  | 31d | 2006-08-01 | 2006-08-31 |  |  |  | 2006-08-01 | 2006-08-31 | 31d | 92d | 0d | start no earlier than 2006-08-01 | Teague [20%] | 49.6h |  |
| 166 | 2.1.4 | System Update |  | 30d | 2006-09-01 | 2006-09-30 | 165 |  |  | 2006-09-01 | 2006-09-30 | 30d | 92d |  |  |  |  |  |
| 167 | 2.1.5 | **GDAAC/MODAPS** |  | 88d | 2006-01-01 A | 2006-03-29 A |  | 100% |  | 2006-01-01 | 2006-03-29 | 88d |  |  |  |  | 163.2h | 163.2h |
| 168 | 2.1.5.1 | Determine Schedule (1.1.5.1) |  | 59d | 2006-01-01 A | 2006-02-28 A |  | 100% |  | 2006-01-01 | 2006-02-28 | 59d |  |  | start no earlier than 2006-01-01 | Teague [20%] | 94.4h | 94.4h |
| 169 | 2.1.5.2 | Detailed Meetings (1.1.5.2) |  | 43d | 2006-02-15 A | 2006-03-29 A |  | 100% |  | 2006-02-15 | 2006-03-29 | 43d |  |  | start no earlier than 2006-02-15 | Teague [5%]; DeShong [15%] | 68.8h | 68.8h |
| 170 | 2.2 | **Subscriptions** |  | 334d? | 2006-02-01 A | 2006-12-31 |  | 9% | 303.02d? | 2006-02-01 | 2006-10-01 | 243d? | 0d |  |  |  | 645.6h | 101.86h |
| 171 | 2.2.1 | **MODAPS** |  | 334d | 2006-02-01 A | 2006-12-31 |  | 9% | 302.95d | 2006-02-01 | 2006-10-01 | 243d | 0d |  |  |  | 645.6h | 101.86h |
| 172 | 2.2.1.1 | **Collection 4** |  | 155d | 2006-02-01 A | 2006-07-05 |  | 44% | 87.37d | 2006-02-01 | 2006-07-01 | 151d | 0d |  |  |  | 35.68h | 28.42h |
| 173 | 2.2.1.1.1 | Review C4 L1B (6.1.1) |  | 20d | 2006-02-01 A | 2006-02-20 A |  | 100% |  | 2006-02-01 | 2006-02-20 | 20d |  |  | start no earlier than 2006-02-01 | DeShong [5%] | 8h | 8h |
| 174 | 2.2.1.1.2 | Est C4 Atmos (6.1.1) |  | 11d | 2006-02-16 A | 2006-02-26 A |  | 100% |  | 2006-02-16 | 2006-03-03 | 16d |  |  |  | DeShong [5%] | 4.4h | 4.4h |
| 175 | 2.2.1.1.3 | Test C4 Atmos (4.1.2) |  | 4d | 2006-02-26 A | 2006-03-01 A |  | 100% |  | 2006-03-01 | 2006-03-07 | 7d |  |  | start no earlier than 2006-02-28 | DeShong [5%] | 1.6h | 1.6h |
| 176 | 2.2.1.1.4 | ITRR (1.1.4.2) |  | 5d | 2006-03-02 A | 2006-03-06 A | 175 | 100% |  | 2006-03-08 | 2006-03-10 | 3d |  |  |  | Teague [30%] | 12h | 12h |
| 177 | 2.2.1.1.5 | Start C4 Atmos (6.1.3) |  | 121d | 2006-03-07 A | 2006-07-05 | 176 | 25% | 90.75d | 2006-03-11 | 2006-06-30 | 112d | 0d |  |  | Shiles [1%] | 9.68h | 2.42h |
| 178 | 2.2.1.2 | **Collection 5** |  | 306d | 2006-03-01 A | 2006-12-31 |  | 6% | 288.82d | 2006-03-01 | 2006-10-01 | 215d | 0d |  |  |  | 609.92h | 73.44h |
| 179 | 2.2.1.2.1 | **Est C5 L1B (6.1.1)** |  | 109d | 2006-03-01 A | 2006-06-17 |  | 51% | 52.94d | 2006-03-01 | 2006-06-17 | 109d | 6d |  |  | Shiles [5%] | 57.6h | 29.62h |
| 180 | 2.2.1.2.1.1 | Aqua |  | 18d | 2006-03-01 A | 2006-03-18 A |  | 100% |  | 2006-03-01 | 2006-03-18 | 18d |  |  | start no earlier than 2006-03-01 | DeShong [5%] | 7.2h | 7.2h |
| 181 | 2.2.1.2.1.2 | Terra |  | 17d | 2006-06-01 | 2006-06-17 |  |  |  | 2006-06-01 | 2006-06-17 | 17d | 6d | 0d | start no earlier than 2006-06-01 | DeShong [5%] | 6.8h |  |

| ID | WBS | Task | Duration | Start | Finish | Predecessors | Complete | Remaining | Baseline start | Baseline finish | Baseline duration | Total slack | Free slack | Constraint | Resources | Work | Actual work |
| --- | --- | --- | --- | --- | --- | --- | --- | --- | --- | --- | --- | --- | --- | --- | --- | --- | --- |
| 182 | 2.2.1.2.2 | **Test L1B C5 (4.1.1)** | 108d | 2006-03-12 A | 2006-06-27 |  | 60% | 43.2d | 2006-03-19 | 2006-06-27 | 101d | 187d |  |  |  | 13.6h | 8.16h |
| 183 | 2.2.1.2.2.1 | Aqua | 24d | 2006-03-12 A | 2006-04-04 |  | 85% | 3.6d | 2006-03-19 | 2006-03-28 | 10d | 271d |  | start no earlier than 2006-03-12 | Fu [5%] | 9.6h | 8.16h |
| 184 | 2.2.1.2.2.2 | Terra | 10d | 2006-06-18 | 2006-06-27 | 181 |  |  | 2006-06-18 | 2006-06-27 | 10d | 6d | 0d | start no earlier than 2006-06-18 | Fu [5%] | 4h |  |
| 185 | 2.2.1.2.3 | **ITRR (1.1.4.1)** | 94d | 2006-03-29 A | 2006-06-30 |  | 42% | 54.52d | 2006-03-29 | 2006-06-30 | 94d | 6d |  |  |  | 16h | 6.72h |
| 186 | 2.2.1.2.3.1 | Aqua | 7d | 2006-03-29 A | 2006-04-04 |  | 60% | 2.8d | 2006-03-29 | 2006-03-31 | 3d | 1d | 0d | start no earlier than 2006-03-29 | Teague [20%] | 11.2h | 6.72h |
| 187 | 2.2.1.2.3.2 | Terra | 3d | 2006-06-28 | 2006-06-30 | 184 |  |  | 2006-06-28 | 2006-06-30 | 3d | 6d | 5d | start no earlier than 2006-06-28 | Teague [20%] | 4.8h |  |
| 188 | 2.2.1.2.4 | **C5 L1B Ops (6.1.2)** | 270d | 2006-04-05 | 2006-12-30 |  |  |  | 2006-04-01 | 2006-09-30 | 183d | 1d |  |  |  | 142.88h |  |
| 189 | 2.2.1.2.4.1 | Aqua | 270d | 2006-04-05 | 2006-12-30 | 186, 265SS |  |  | 2006-04-01 | 2006-12-31 | 275d | 1d | 0d | start no earlier than 2006-04-01 | Shiles [2%] | 43.2h |  |
| 190 | 2.2.1.2.4.2 | Terra | 178d | 2006-07-06 | 2006-12-30 | 187, 266SS |  |  | 2006-07-01 | 2006-12-30 | 183d | 1d | 0d | start no earlier than 2006-07-01 | Shiles [7%] | 99.68h |  |
| 191 | 2.2.1.2.5 | **Est C5 Atmos (6.1.1)** | 109d | 2006-03-01 A | 2006-06-17 |  | 51% | 52.94d | 2006-03-01 | 2006-06-17 | 109d | 5d |  |  |  | 28h | 14.4h |
| 192 | 2.2.1.2.5.1 | Aqua | 18d | 2006-03-01 A | 2006-03-18 A |  | 100% |  | 2006-03-01 | 2006-03-18 | 18d |  |  | start no earlier than 2006-03-01 | DeShong [5%]; AD Manager [5%] | 14.4h | 14.4h |
| 193 | 2.2.1.2.5.2 | Terra | 17d | 2006-06-01 | 2006-06-17 |  |  |  | 2006-06-01 | 2006-06-17 | 17d | 5d | 0d | start no earlier than 2006-06-01 | DeShong [5%]; AD Manager [5%] | 13.6h |  |
| 194 | 2.2.1.2.6 | **Test C5 Atmos (4.1.2)** | 106d | 2006-03-14 A | 2006-06-27 |  | 59% | 43.2d | 2006-03-19 | 2006-06-27 | 101d | 187d |  |  |  | 13.2h | 7.82h |
| 195 | 2.2.1.2.6.1 | Aqua | 23d | 2006-03-14 A | 2006-04-05 |  | 85% | 3.45d | 2006-03-19 | 2006-03-28 | 10d | 270d |  | start no earlier than 2006-03-14 | Fu [5%] | 9.2h | 7.82h |
| 196 | 2.2.1.2.6.2 | Terra | 10d | 2006-06-18 | 2006-06-27 | 193 |  |  | 2006-06-18 | 2006-06-27 | 10d | 5d | 0d | start no earlier than 2006-06-18 | Fu [5%] | 4h |  |
| 197 | 2.2.1.2.7 | **ITRR (1.1.4.2)** | 94d | 2006-03-29 A | 2006-06-30 |  | 42% | 54.52d | 2006-03-29 | 2006-06-30 | 94d | 5d |  |  |  | 16h | 6.72h |
| 198 | 2.2.1.2.7.1 | Aqua | 7d | 2006-03-29 A | 2006-04-04 |  | 60% | 2.8d | 2006-03-29 | 2006-03-31 | 3d | 1d | 0d | start no earlier than 2006-03-29 | Teague [20%] | 11.2h | 6.72h |
| 199 | 2.2.1.2.7.2 | Terra | 3d | 2006-06-28 | 2006-06-30 | 196 |  |  | 2006-06-28 | 2006-06-30 | 3d | 5d |  | start no earlier than 2006-06-28 | Teague [20%] | 4.8h |  |
| 200 | 2.2.1.2.8 | **C5 Atmos Ops (6.1.3)** | 271d | 2006-04-05 | 2006-12-31 |  |  |  | 2006-04-01 | 2006-10-01 | 184d | 0d |  |  |  | 143.44h |  |
| 201 | 2.2.1.2.8.1 | Aqua | 270d | 2006-04-05 | 2006-12-30 | 198, 279SS |  |  | 2006-04-01 | 2006-12-30 | 274d | 1d |  | start no earlier than 2006-04-01 | Shiles [2%] | 43.2h |  |
| 202 | 2.2.1.2.8.2 | Terra | 179d | 2006-07-06 | 2006-12-31 | 199, 177, 280SS |  |  | 2006-07-02 | 2006-12-31 | 183d | 0d |  | start no earlier than 2006-07-01 | Shiles [7%] | 100.24h |  |
| 203 | 2.2.1.2.9 | **GDAAC Subs (6.1.5)** | 270d | 2006-04-05 | 2006-12-30 |  |  |  | 2006-04-01 | 2006-12-30 | 274d | 1d |  |  |  | 179.2h |  |
| 204 | 2.2.1.2.9.1 | Aqua | 270d | 2006-04-05 | 2006-12-30 |  |  |  | 2006-04-01 | 2006-12-30 | 274d | 1d |  | start no earlier than 2006-04-05 | Shiles [5%] | 108h |  |
| 205 | 2.2.1.2.9.2 | Terra | 178d | 2006-07-06 | 2006-12-30 |  |  |  | 2006-07-01 | 2006-12-29 | 182d | 1d |  | start no earlier than 2006-07-06 | Shiles [5%] | 71.2h |  |

| ID | WBS | Task | Type | Duration | Start | Finish | Predecessors | Complete | Remaining | Baseline start | Baseline finish | Baseline duration | Total slack | Free slack | Constraint | Resources | Work | Actual work |
| --- | --- | --- | --- | --- | --- | --- | --- | --- | --- | --- | --- | --- | --- | --- | --- | --- | --- | --- |
| 206 | 2.2.2 | **GDAAC** |  | 129d? | 2006-02-28 | 2006-07-06 |  |  |  | 2006-02-28 | 2006-07-01 | 124d? | 178d |  |  |  |  |  |
| 207 | 2.2.2.1 | Stop L1B C4 | milestone | 1d? | 2006-02-28 | 2006-02-28 |  |  |  | 2006-02-28 | 2006-02-28 | 1d? | 306d |  | start no earlier than 2006-02-28 |  |  |  |
| 208 | 2.2.2.2 | Stop Atmos C4 | milestone | 1d? | 2006-03-07 | 2006-03-07 | 177SS |  |  | 2006-03-11 | 2006-03-11 | 1d? | 299d |  | start no earlier than 2006-03-04 |  |  |  |
| 209 | 2.2.2.3 | **Stop L1B C5** |  | 93d? | 2006-04-05 | 2006-07-06 |  |  |  | 2006-04-01 | 2006-07-01 | 92d? | 178d |  |  |  |  |  |
| 210 | 2.2.2.3.1 | Aqua | milestone | 1d? | 2006-04-05 | 2006-04-05 | 189SS |  |  | 2006-04-01 | 2006-04-01 | 1d? | 270d |  | start no earlier than 2006-04-01 |  |  |  |
| 211 | 2.2.2.3.2 | Terra | milestone | 1d? | 2006-07-06 | 2006-07-06 | 190SS |  |  | 2006-07-01 | 2006-07-01 | 1d? | 178d |  | start no earlier than 2006-07-01 |  |  |  |
| 212 | 2.3 | **Subsetters** |  | 350d? | 2006-01-15 A | 2006-12-30 |  | 11% | 311.6d? | 2006-01-15 | 2006-10-01 | 260d? | 1d |  |  |  | 362h | 126.44h |
| 213 | 2.3.1 | **MODAPS** |  | 350d? | 2006-01-15 A | 2006-12-30 |  | 11% | 311.53d? | 2006-01-15 | 2006-10-01 | 260d? | 1d |  |  |  | 362h | 126.44h |
| 214 | 2.3.1.1 | Review GDAAC Lists (1.10.2) |  | 80d | 2006-01-15 A | 2006-04-04 A |  | 100% |  | 2006-01-15 | 2006-03-05 | 50d |  |  | start no earlier than 2006-01-15 | Teague [5%]; Ridgway [5%] | 64h | 64h |
| 215 | 2.3.1.2 | **CERES** |  | 333d | 2006-02-01 A | 2006-12-30 |  | 8% | 307.21d | 2006-02-01 | 2006-10-01 | 243d | 1d |  |  |  | 206.32h | 42.44h |
| 216 | 2.3.1.2.1 | Install C4/C5 (3.1.1) |  | 15d | 2006-02-01 A | 2006-02-15 A |  | 100% |  | 2006-02-01 | 2006-02-15 | 15d |  |  | start no earlier than 2006-02-01 | Kuyper [15%] | 18h | 18h |
| 217 | 2.3.1.2.2 | Test C4 (4.2.1) |  | 6d | 2006-02-16 A | 2006-02-21 A | 216 | 100% |  | 2006-02-16 | 2006-02-25 | 10d |  |  |  | DeShong [5%] | 2.4h | 2.4h |
| 218 | 2.3.1.2.3 | ITRR (1.1.4.3) |  | 3d | 2006-02-22 A | 2006-02-24 A | 217 | 100% |  | 2006-02-26 | 2006-02-28 | 3d |  |  |  | Teague [20%] | 4.8h | 4.8h |
| 219 | 2.3.1.2.4 | C4 Ops (6.2.1.1) |  | 126d | 2006-02-25 A | 2006-06-30 | 218 | 22% | 98.28d | 2006-03-01 | 2006-06-30 | 122d | 6d | 4d |  | Shiles [2%] | 20.16h | 4.44h |
| 220 | 2.3.1.2.5 | Test C5 A/T (4.2.1) |  | 32d | 2006-03-01 A | 2006-04-01 A |  | 100% |  | 2006-03-01 | 2006-03-28 | 28d |  |  | start no earlier than 2006-03-01 | DeShong [5%] | 12.8h | 12.8h |
| 221 | 2.3.1.2.6 | ITRR (1.1.4.3) |  | 3d | 2006-04-02 | 2006-04-04 | 220 |  |  | 2006-03-29 | 2006-03-31 | 3d | 1d | 0d |  | Teague [20%] | 4.8h |  |
| 222 | 2.3.1.2.7 | **C5 Fwd Ops (6.2.1.2.1)** |  | 270d | 2006-04-05 | 2006-12-30 |  |  |  | 2006-04-01 | 2006-09-30 | 183d | 1d |  |  |  | 71.68h |  |
| 223 | 2.3.1.2.7.1 | Aqua |  | 270d | 2006-04-05 | 2006-12-30 | 221, 265SS |  |  | 2006-04-01 | 2006-12-29 | 273d | 1d |  | start no earlier than 2006-04-01 | Shiles [2%] | 43.2h |  |
| 224 | 2.3.1.2.7.2 | Terra |  | 178d | 2006-07-06 | 2006-12-30 | 219, 266SS |  |  | 2006-07-01 | 2006-12-30 | 183d | 1d |  | start no earlier than 2006-07-01 | Shiles [2%] | 28.48h |  |
| 225 | 2.3.1.2.8 | **C5 Repro Ops (6.2.1.2.2)** |  | 270d | 2006-04-05 | 2006-12-30 |  |  |  | 2006-04-01 | 2006-12-30 | 274d | 1d |  |  |  | 71.68h |  |
| 226 | 2.3.1.2.8.1 | Aqua |  | 270d | 2006-04-05 | 2006-12-30 | 279SS |  |  | 2006-04-01 | 2006-12-30 | 274d | 1d |  | start no earlier than 2006-04-01 | Shiles [2%] | 43.2h |  |
| 227 | 2.3.1.2.8.2 | Terra |  | 178d | 2006-07-06 | 2006-12-30 | 280SS |  |  | 2006-07-02 | 2006-12-30 | 182d | 1d |  | start no earlier than 2006-07-01 | Shiles [2%] | 28.48h |  |
| 228 | 2.3.1.3 | **Miami** |  | 312d | 2006-02-22 A | 2006-12-30 |  | 5% | 295.51d | 2006-03-01 | 2006-09-30 | 214d | 1d |  |  |  | 91.68h | 20h |
| 229 | 2.3.1.3.1 | Install (3.1.2) |  | 8d | 2006-02-22 A | 2006-03-01 A |  | 100% |  | 2006-03-01 | 2006-03-12 | 12d |  |  | start no earlier than 2006-02-25 | Kuyper [15%] | 9.6h | 9.6h |
| 230 | 2.3.1.3.2 | Test C5 (4.2.2) |  | 14d | 2006-03-16 A | 2006-03-29 A | 229 | 100% |  | 2006-03-13 | 2006-03-28 | 16d |  |  | start no earlier than 2006-03-16 | DeShong [5%] | 5.6h | 5.6h |
| 231 | 2.3.1.3.3 | ITRR (1.1.4.4) |  | 3d | 2006-03-30 A | 2006-04-01 A | 230 | 100% |  | 2006-03-29 | 2006-03-31 | 3d |  |  |  | Teague [20%] | 4.8h | 4.8h |

| ID | WBS | Task | Type | Duration | Start | Finish | Predecessors | Complete | Remaining | Baseline start | Baseline finish | Baseline duration | Total slack | Free slack | Constraint | Resources | Work | Actual work |
| --- | --- | --- | --- | --- | --- | --- | --- | --- | --- | --- | --- | --- | --- | --- | --- | --- | --- | --- |
| 232 | 2.3.1.3.4 | **C5 Ops (6.2.2)** |  | 270d | 2006-04-05 | 2006-12-30 |  |  |  | 2006-04-01 | 2006-09-30 | 183d | 1d |  |  |  | 71.68h |  |
| 233 | 2.3.1.3.4.1 | Aqua |  | 270d | 2006-04-05 | 2006-12-30 | 231, 265SS |  |  | 2006-04-01 | 2006-12-30 | 274d | 1d | 0d | start no earlier than 2006-04-01 | Shiles [2%] | 43.2h |  |
| 234 | 2.3.1.3.4.2 | Terra |  | 178d | 2006-07-06 | 2006-12-30 | 266SS |  |  | 2006-07-01 | 2006-12-29 | 182d | 1d | 0d | start no earlier than 2006-07-01 | Shiles [2%] | 28.48h |  |
| 235 | 2.3.1.4 | **Aeronet** |  | 41d? | 2006-04-04 | 2006-05-14 |  |  |  | 2006-04-04 | 2006-05-14 | 41d? | 231d |  |  |  |  |  |
| 236 | 2.3.1.4.1 | Receive Code from Land | milestone | 1d? | 2006-04-04 | 2006-04-04 |  |  |  | 2006-04-04 | 2006-04-04 | 1d? | 231d | 0d | start no earlier than 2006-04-04 |  |  |  |
| 237 | 2.3.1.4.2 | Develop Code |  | 30d | 2006-04-05 | 2006-05-04 | 236 |  |  | 2006-04-05 | 2006-05-04 | 30d | 231d | 0d |  |  |  |  |
| 238 | 2.3.1.4.3 | Operations Test |  | 10d | 2006-05-05 | 2006-05-14 | 237 |  |  | 2006-05-05 | 2006-05-14 | 10d | 231d |  |  |  |  |  |
| 239 | 2.3.1.5 | **Pixel and Band Subsampler** |  | 52d? | 2006-03-28 | 2006-05-18 |  |  |  | 2006-03-28 | 2006-05-18 | 52d? | 227d |  |  |  |  |  |
| 240 | 2.3.1.5.1 | Receive DAP from GDAAC | milestone | 1d? | 2006-03-28 | 2006-03-28 |  |  |  | 2006-03-28 | 2006-03-28 | 1d? | 278d |  | start no earlier than 2006-03-28 |  |  |  |
| 241 | 2.3.1.5.2 | Develop PGE |  | 30d | 2006-04-09 | 2006-05-08 |  |  |  | 2006-04-09 | 2006-05-08 | 30d | 227d | 0d | start no earlier than 2006-04-09 |  |  |  |
| 242 | 2.3.1.5.3 | Operations Test |  | 10d | 2006-05-09 | 2006-05-18 | 241 |  |  | 2006-05-09 | 2006-05-18 | 10d | 227d |  |  |  |  |  |
| 243 | 2.3.1.6 | Other |  | 1d? | 2006-02-16 | 2006-02-16 |  |  |  | 2006-02-16 | 2006-02-16 | 1d? | 318d |  |  |  |  |  |
| 244 | 2.3.2 | **GDAAC** |  | 128d? | 2006-03-01 | 2006-07-06 |  |  |  | 2006-03-01 | 2006-07-01 | 123d? | 178d |  |  |  |  |  |
| 245 | 2.3.2.1 | Stop C4 CERES | milestone | 1d? | 2006-03-01 | 2006-03-01 | 219SS |  |  | 2006-03-01 | 2006-03-01 | 1d? | 305d | 0d | start no earlier than 2006-03-01 |  |  |  |
| 246 | 2.3.2.2 | **Stop C5 Miami** |  | 93d? | 2006-04-05 | 2006-07-06 |  |  |  | 2006-04-01 | 2006-07-01 | 92d? | 178d |  |  |  |  |  |
| 247 | 2.3.2.2.1 | Aqua | milestone | 1d? | 2006-04-05 | 2006-04-05 | 233SS |  |  | 2006-04-01 | 2006-04-01 | 1d? | 270d |  | start no earlier than 2006-04-01 |  |  |  |
| 248 | 2.3.2.2.2 | Terra | milestone | 1d? | 2006-07-06 | 2006-07-06 | 234SS |  |  | 2006-07-01 | 2006-07-01 | 1d? | 178d |  | start no earlier than 2006-07-01 |  |  |  |
| 249 | 2.4 | **MODAPS Prod** |  | 364d? | 2006-01-01 A | 2006-12-30 |  | 18% | 300.05d? | 2006-01-01 | 2006-09-30 | 273d? | 1d |  |  |  | 13117.3h | 2178.01h |
| 250 | 2.4.1 | **Data Acquisition** |  | 364d? | 2006-01-01 A | 2006-12-30 |  | 25% | 273.03d? | 2006-01-01 | 2006-09-30 | 273d? | 1d |  |  |  | 4293.6h | 1060.22h |
| 251 | 2.4.1.1 | Att/Ephem/Anc from GDAAC (6.3.7) |  | 364d | 2006-01-01 A | 2006-12-30 |  | 26% | 269.36d | 2006-01-01 | 2006-12-30 | 364d | 1d |  | start no earlier than 2006-01-01 | Ingest Tech [10%] | 291.2h | 75.71h |
| 252 | 2.4.1.2 | L0 from GDAAC (6.3.4.1) |  | 211d | 2006-01-01 A | 2006-07-30 |  | 45% | 116.05d | 2006-01-01 | 2006-07-30 | 211d | 154d |  | start no earlier than 2006-01-01 | Ingest Tech [10%] | 168.8h | 75.96h |
| 253 | 2.4.1.3 | L0 from EDOS (6.3.4.2) |  | 212d | 2006-06-01 | 2006-12-29 |  |  |  | 2006-06-01 | 2006-12-29 | 212d | 2d | 0d | start no earlier than 2006-06-01 | Ingest Tech [20%] | 339.2h |  |
| 254 | 2.4.1.4 | Maintain MODAPS L0 (6.4.4.1) |  | 364d | 2006-01-01 A | 2006-12-30 |  | 26% | 269.36d | 2006-01-01 | 2006-12-30 | 364d | 1d |  | start no earlier than 2006-01-01 | Ingest Tech [20%] | 582.4h | 151.42h |
| 255 | 2.4.1.5 | GDAAC Maintain L0 archive |  | 364d | 2006-01-01 A | 2006-12-30 |  | 26% | 269.36d | 2006-01-01 | 2006-12-30 | 364d | 1d |  | start no earlier than 2006-01-01 | GDAAC | 2912h | 757.12h |
| 256 | 2.4.1.6 | Stop EDOS to GDAAC transfer | milestone | 1d? | 2006-08-20 | 2006-08-20 |  |  |  | 2006-08-20 | 2006-08-20 | 1d? | 133d |  | start no earlier than 2006-08-20 |  |  |  |

| ID | WBS | Task | Type | Duration | Start | Finish | Predecessors | Complete | Remaining | Baseline start | Baseline finish | Baseline duration | Total slack | Free slack | Constraint | Resources | Work | Actual work |
| --- | --- | --- | --- | --- | --- | --- | --- | --- | --- | --- | --- | --- | --- | --- | --- | --- | --- | --- |
| 257 | 2.4.2 | **C4 Forward Prod (6.3.1)** |  | 212d | 2006-01-01 A | 2006-07-31 |  | 53% | 100.61d | 2006-01-01 | 2006-07-31 | 212d | 1d |  |  |  | 1570.16h | 810.41h |
| 258 | 2.4.2.1 | **Atmos (6.3.1.1)** |  | 186d | 2006-01-01 A | 2006-07-05 |  | 66% | 63.65d | 2006-01-01 | 2006-06-30 | 181d | 1d |  |  |  | 560h | 368.36h |
| 259 | 2.4.2.1.1 | Aqua |  | 94d | 2006-01-01 A | 2006-04-04 |  | 97% | 2.82d | 2006-01-01 | 2006-03-31 | 90d | 0d |  | start no earlier than 2006-01-01 | Do [7%]; McMillan [7%]; Shiles [5%]; DeShong [5%]; Teague [1%] | 188h | 182.36h |
| 260 | 2.4.2.1.2 | Terra |  | 186d | 2006-01-01 A | 2006-07-05 |  | 50% | 93d | 2006-01-01 | 2006-06-30 | 181d | 1d | 0d | start no earlier than 2006-01-01 | Do [7%]; McMillan [7%]; Shiles [5%]; DeShong [5%]; Teague [1%] | 372h | 186h |
| 261 | 2.4.2.2 | Land (6.3.1.2) |  | 212d | 2006-01-01 A | 2006-07-31 |  | 44% | 118.72d | 2006-01-01 | 2006-07-31 | 212d | 1d | 0d | start no earlier than 2006-01-01 | Do [15%]; McMillan [15%]; Shiles [10%]; DeShong [15%]; Teague [1%] | 949.76h | 417.89h |
| 262 | 2.4.2.3 | C4 L1B POD (6.3.1.3) |  | 151d | 2006-02-05 A | 2006-07-05 |  | 40% | 90.6d | 2006-02-05 | 2006-06-30 | 146d | 1d | 0d | start no earlier than 2006-02-05 | Shiles [5%] | 60.4h | 24.16h |
| 263 | 2.4.3 | **C5 Forward Prod (6.3.2)** |  | 270d | 2006-04-05 | 2006-12-30 |  |  |  | 2006-04-01 | 2006-09-30 | 183d | 0d |  |  |  | 2127.84h |  |
| 264 | 2.4.3.1 | **C5 Atmos (6.3.2.1)** |  | 270d | 2006-04-05 | 2006-12-30 |  |  |  | 2006-04-01 | 2006-09-30 | 183d | 0d |  |  |  | 1337.44h |  |
| 265 | 2.4.3.1.1 | Aqua |  | 270d | 2006-04-05 | 2006-12-30 | 259 |  |  | 2006-04-01 | 2006-12-30 | 274d | 0d |  | start no earlier than 2006-04-05 | Do [7%]; McMillan [7%]; Shiles [5%]; DeShong [5%]; Teague [1%] | 540h |  |
| 266 | 2.4.3.1.2 | Terra |  | 178d | 2006-07-06 | 2006-12-30 | 260, 262 |  |  | 2006-07-01 | 2006-12-30 | 183d | 1d | 0d | start no earlier than 2006-07-06 | Shiles [10%]; DeShong [5%]; Teague [1%]; Do [20%]; McMillan [20%] | 797.44h |  |
| 267 | 2.4.3.2 | C5 Land (6.3.2.2) |  | 152d | 2006-08-01 | 2006-12-30 | 261 |  |  | 2006-08-01 | 2006-12-29 | 151d | 1d |  | start no earlier than 2006-08-01 | Do [20%]; McMillan [20%]; DeShong [25%] | 790.4h |  |
| 268 | 2.4.4 | **POD** |  | 330d? | 2006-02-04 A | 2006-12-30 |  | 12% | 289.03d? | 2006-02-04 | 2006-09-30 | 239d? | 1d |  |  |  | 903.6h | 209.59h |
| 269 | 2.4.4.1 | LAADS Load Tests (2.1.3) |  | 31d | 2006-04-11 | 2006-05-11 |  |  |  | 2006-04-11 | 2006-05-11 | 31d | 234d |  | start no earlier than 2006-04-11 | Ye [10%]; Sinno [10%] | 49.6h |  |
| 270 | 2.4.4.2 | L1B C5 Test (2.1.1) |  | 71d | 2006-02-04 A | 2006-04-15 |  | 82% | 12.78d | 2006-02-04 | 2006-04-11 | 67d | 255d | 0d | finish no earlier than 2006-03-15 | Ye [10%]; Devine [10%]; Warman [10%]; Ridgway [10%]; Sinno [5%] | 255.6h | 209.59h |
| 271 | 2.4.4.3 | ITRR (1.1.4.6) |  | 5d | 2006-04-16 | 2006-04-20 | 277FS+7d, 270 |  |  | 2006-04-12 | 2006-04-16 | 5d | 255d |  | start no earlier than 2006-03-31 | Teague [20%] | 8h |  |
| 272 | 2.4.4.4 | L1B Ops (6.3.1.3) |  | 270d | 2006-04-05 | 2006-12-30 | 265SS |  |  | 2006-04-01 | 2006-12-30 | 274d | 0d |  | start no earlier than 2006-04-01 | Warman [15%]; Teague [2%]; AD Manager [2%] | 410.4h |  |
| 273 | 2.4.4.5 | Land C5 Test (2.1.2) |  | 90d | 2006-06-01 | 2006-08-29 |  |  |  | 2006-06-01 | 2006-08-29 | 90d | 124d |  | start no earlier than 2006-06-01 | Ye [5%]; Devine [5%]; Warman [5%]; Saleous [5%]; Sinno [5%] | 180h |  |
| 274 | 2.4.4.6 | ITRR |  | 1d? | 2006-02-16 | 2006-02-16 |  |  |  | 2006-02-16 | 2006-02-16 | 1d? | 318d |  |  |  |  |  |
| 275 | 2.4.4.7 | Land Ops (6.3.2.4) |  | 1d? | 2006-02-16 | 2006-02-16 |  |  |  | 2006-02-16 | 2006-02-16 | 1d? | 318d |  |  |  |  |  |
| 276 | 2.4.5 | **C5 Reprocessing (6.3.3)** |  | 270d? | 2006-04-05 | 2006-12-30 |  |  |  | 2006-04-01 | 2006-09-30 | 183d | 0d |  |  |  | 2682.93h |  |
| 277 | 2.4.5.1 | Install Hardware |  | 2d | 2006-04-07 | 2006-04-08 |  |  |  | 2006-04-03 | 2006-04-04 | 2d | 255d | 0d | start no earlier than 2006-04-07 |  |  |  |
| 278 | 2.4.5.2 | **Atmospheres (6.3.3.1)** |  | 247d? | 2006-04-05 | 2006-12-07 |  |  |  | 2006-04-01 | 2006-09-30 | 183d | 0d |  |  |  | 1486.86h |  |
| 279 | 2.4.5.2.1 | Aqua |  | 92d | 2006-04-05 | 2006-07-05 | 272SS |  |  | 2006-04-01 | 2006-07-01 | 92d | 0d |  | start no earlier than 2006-04-05 | McMillan [17%]; DeShong [9%]; Shiles [6%]; Teague [1%]; Do [35%] | 460.54h |  |
| 280 | 2.4.5.2.2 | Terra |  | 155d | 2006-07-06 | 2006-12-07 | 279 |  |  | 2006-07-02 | 2006-12-30 | 182d | 0d |  |  | DeShong [9%]; Shiles [6%]; Teague [1%]; Do [35%]; McMillan [35%] | 982.31h |  |
| 281 | 2.4.5.2.3 | Complete Aqua 1/05-3/06 | milestone | 1d? | 2006-05-05 | 2006-05-05 |  |  |  |  |  |  | 230d | 0d | start no earlier than 2006-05-05 |  |  |  |
| 282 | 2.4.5.2.4 | Complete Terra 05, 2/00-2/02 | milestone | 1d? | 2006-09-15 | 2006-09-15 |  |  |  | 2006-09-15 | 2006-09-15 | 1d? | 107d | 0d | start no earlier than 2006-09-15 |  |  |  |
| 283 | 2.4.5.2.5 | Backup Exp GDAAC (6.4.1.5) |  | 110d | 2006-04-05 | 2006-07-23 | 279SS |  |  | 2006-04-01 | 2006-07-19 | 110d | 161d |  | start no earlier than 2006-04-01 | Shiles [5%] | 44h |  |

| ID | WBS | Task | Type | Duration | Start | Finish | Predecessors | Complete | Remaining | Baseline start | Baseline finish | Baseline duration | Total slack | Free slack | Constraint | Resources | Work | Actual work |
| --- | --- | --- | --- | --- | --- | --- | --- | --- | --- | --- | --- | --- | --- | --- | --- | --- | --- | --- |
| 284 | 2.4.5.3 | **Land (6.3.3.2)** |  | 259d | 2006-04-16 | 2006-12-30 |  |  |  | 2006-04-01 | 2006-09-30 | 183d | 1d |  |  |  | 1196.07h |  |
| 285 | 2.4.5.3.1 | Prod |  | 259d | 2006-04-16 | 2006-12-30 |  |  |  | 2006-04-01 | 2006-12-30 | 274d | 1d | 0d | start no earlier than 2006-04-16 | Do [35%]; McMillan [35%]; Shiles [13%]; DeShong [17%]; Teague [1%] | 1092.47h |  |
| 286 | 2.4.5.3.2 | Export LP DAAC |  | 259d | 2006-04-16 | 2006-12-30 | 285SS |  |  | 2006-04-01 | 2006-12-30 | 274d | 1d |  | start no earlier than 2006-04-01 | Shiles [5%] | 103.6h |  |
| 287 | 2.4.6 | Ad-hoc Prod (6.3.6) |  | 350d | 2006-01-15 A | 2006-12-30 |  | 25% | 262.5d | 2006-01-15 | 2006-12-30 | 350d | 1d |  | start no earlier than 2006-01-15 | Shiles [10%] | 280h | 70h |
| 288 | 2.4.7 | Disk Maintenance |  | 270d | 2006-04-05 | 2006-12-30 |  |  |  | 2006-04-01 | 2006-12-30 | 274d | 1d |  | start no earlier than 2006-04-05 | Ingest Tech [25%]; DeShong [25%] | 1080h |  |
| 289 | 2.4.8 | **Convert L0 to 5min (6.4.4.3)** |  | 318d | 2006-02-16 A | 2006-12-30 |  | 12% | 278.55d | 2006-02-16 | 2006-09-30 | 227d | 1d |  |  |  | 179.2h | 27.79h |
| 290 | 2.4.8.1 | Test Splitter |  | 13d | 2006-02-16 A | 2006-02-28 A |  | 100% |  | 2006-02-16 | 2006-03-07 | 20d |  |  |  | DeShong [5%]; Kuyper [5%] | 10.4h | 10.4h |
| 291 | 2.4.8.2 | **Convert MODAPS Archive** |  | 305d | 2006-03-01 A | 2006-12-30 |  | 11% | 272.91d | 2006-03-01 | 2006-09-30 | 214d | 1d |  |  |  | 168.8h | 17.39h |
| 292 | 2.4.8.2.1 | Forward data |  | 305d | 2006-03-01 A | 2006-12-30 |  | 11% | 271.34d | 2006-03-01 | 2006-12-30 | 305d | 1d |  | start no earlier than 2006-03-01 | Ingest Tech [2%] | 48.8h | 5.39h |
| 293 | 2.4.8.2.2 | Reprocessed data |  | 300d | 2006-03-06 A | 2006-12-30 |  | 10% | 270d | 2006-03-14 | 2006-12-30 | 292d | 1d |  | start no earlier than 2006-03-06 | Ingest Tech [5%] | 120h | 12h |
| 294 | 2.5 | **GDAAC Prod & Dist** |  | 199d? | 2006-03-01 | 2006-09-15 |  |  |  | 2006-03-01 | 2006-08-01 | 154d? | 107d |  |  |  |  |  |
| 295 | 2.5.1 | Stop C4 Forward | milestone | 1d? | 2006-03-01 | 2006-03-01 | 245SS |  |  | 2006-03-01 | 2006-03-01 | 1d? | 305d |  | start no earlier than 2006-03-01 |  |  |  |
| 296 | 2.5.2 | **C5 Forward** |  | 114d? | 2006-04-10 | 2006-08-01 |  |  |  | 2006-04-01 | 2006-08-01 | 123d? | 152d |  |  |  |  |  |
| 297 | 2.5.2.1 | **Aqua** |  | 36d? | 2006-04-10 | 2006-05-15 |  |  |  | 2006-04-01 | 2006-05-01 | 31d? | 230d |  |  |  |  |  |
| 298 | 2.5.2.1.1 | Stop Prod | milestone | 1d? | 2006-04-10 | 2006-04-10 |  |  |  | 2006-04-10 | 2006-04-10 | 1d? | 265d |  | start no earlier than 2006-04-10 |  |  |  |
| 299 | 2.5.2.1.2 | Stop Dist | milestone | 1d? | 2006-05-15 | 2006-05-15 | 265SS, 279SS, 316SS+10d |  |  | 2006-05-15 | 2006-05-15 | 1d? | 230d |  | start no earlier than 2006-05-15 |  |  |  |
| 300 | 2.5.2.2 | **Terra** |  | 27d? | 2006-07-06 | 2006-08-01 |  |  |  | 2006-07-02 | 2006-08-01 | 31d? | 152d |  |  |  |  |  |
| 301 | 2.5.2.2.1 | Stop Prod | milestone | 1d? | 2006-08-01 | 2006-08-01 |  |  |  | 2006-08-01 | 2006-08-01 | 1d? | 152d |  | start no earlier than 2006-08-01 |  |  |  |
| 302 | 2.5.2.2.2 | Stop Dist | milestone | 1d? | 2006-07-06 | 2006-07-06 | 266SS, 280SS |  |  | 2006-07-02 | 2006-07-02 | 1d? | 178d |  | start no earlier than 2006-07-01 |  |  |  |
| 303 | 2.5.3 | **C5 Reproc** |  | 124d? | 2006-05-15 | 2006-09-15 |  |  |  | 2006-04-01 | 2006-08-01 | 123d? | 107d |  |  |  |  |  |
| 304 | 2.5.3.1 | **Aqua** |  | 18d? | 2006-05-15 | 2006-06-01 |  |  |  | 2006-04-01 | 2006-05-01 | 31d? | 213d |  |  |  |  |  |
| 305 | 2.5.3.1.1 | Stop Prod | milestone | 1d? | 2006-06-01 | 2006-06-01 |  |  |  | 2006-06-01 | 2006-06-01 | 1d? | 213d |  | start no earlier than 2006-06-01 |  |  |  |
| 306 | 2.5.3.1.2 | Stop Dist | milestone | 1d? | 2006-05-15 | 2006-05-15 | 281SS+10d |  |  | 2006-05-15 | 2006-05-15 | 1d? | 230d | 0d |  |  |  |  |
| 307 | 2.5.3.2 | **Terra** |  | 1d? | 2006-09-15 | 2006-09-15 |  |  |  | 2006-07-02 | 2006-08-01 | 31d? | 107d |  |  |  |  |  |
| 308 | 2.5.3.2.1 | Stop Prod | milestone | 1d? | 2006-09-15 | 2006-09-15 |  |  |  | 2006-09-15 | 2006-09-15 | 1d? | 107d |  | start no earlier than 2006-09-15 |  |  |  |
| 309 | 2.5.3.2.2 | Stop Dist | milestone | 1d? | 2006-09-15 | 2006-09-15 | 282SS |  |  | 2006-09-15 | 2006-09-15 | 1d? | 107d |  | start no earlier than 2006-07-01 |  |  |  |

| ID | WBS | Task | Type | Duration | Start | Finish | Predecessors | Complete | Remaining | Baseline start | Baseline finish | Baseline duration | Total slack | Free slack | Constraint | Resources | Work | Actual work |
| --- | --- | --- | --- | --- | --- | --- | --- | --- | --- | --- | --- | --- | --- | --- | --- | --- | --- | --- |
| 310 | 2.6 | **MODAPS Archive/Dist (6.4)** |  | 364d? | 2006-01-01 A | 2006-12-30 |  | 11% | 323.11d? | 2006-01-01 | 2006-09-30 | 273d | 1d |  |  |  | 3799.31h | 450.78h |
| 311 | 2.6.1 | Hire AD Manager | milestone | 1d? | 2006-04-03 | 2006-04-03 |  |  |  | 2006-04-03 | 2006-04-03 | 1d? | 272d |  | start no earlier than 2006-04-03 |  |  |  |
| 312 | 2.6.2 | **C5 Atmospheres (6.4.1)** |  | 364d | 2006-01-01 A | 2006-12-30 |  | 19% | 293.34d | 2006-01-01 | 2006-09-30 | 273d | 1d |  |  |  | 2069.15h | 450.78h |
| 313 | 2.6.2.1 | Archive in LAADS (6.4.1.1) |  | 364d | 2006-01-01 A | 2006-12-30 |  | 26% | 269.36d | 2006-01-01 | 2006-12-30 | 364d | 1d |  | start no earlier than 2006-01-01 | Warman [20%]; AD Manager [30%]; Sinno [3%] | 1543.36h | 401.27h |
| 314 | 2.6.2.2 | ST Support (6.4.1.3) |  | 364d | 2006-01-01 A | 2006-12-30 |  | 26% | 269.36d | 2006-01-01 | 2006-12-30 | 364d | 1d |  | start no earlier than 2006-01-01 | Warman [5%]; AD Manager [5%] | 264.99h | 49.5h |
| 315 | 2.6.2.3 | ITRR (1.1.4.7) |  | 7d | 2006-04-28 | 2006-05-04 |  |  |  | 2006-04-28 | 2006-05-04 | 7d | 1d | 0d | start no earlier than 2006-04-28 | Teague [20%] | 11.2h |  |
| 316 | 2.6.2.4 | Wide Comm Support (6.4.1.4) |  | 240d | 2006-05-05 | 2006-12-30 | 315 |  |  | 2006-05-01 | 2006-12-29 | 243d | 1d | 0d | start no earlier than 2006-05-05 | Warman [5%]; Teague [3%]; AD Manager [5%] | 249.6h |  |
| 317 | 2.6.3 | **C5 Land (6.4.2)** |  | 259d | 2006-04-16 | 2006-12-30 |  |  |  | 2006-04-01 | 2006-12-30 | 274d | 1d |  |  |  | 1616.16h |  |
| 318 | 2.6.3.1 | Archive in LAADS (6.4.2.1) |  | 259d | 2006-04-16 | 2006-12-30 | 285SS |  |  | 2006-04-01 | 2006-12-30 | 274d | 1d | 0d | start no earlier than 2006-04-01 | Warman [20%]; AD Manager [35%]; Sinno [3%] | 1201.76h |  |
| 319 | 2.6.3.2 | ST Support (6.4.2.2) |  | 259d | 2006-04-16 | 2006-12-30 | 318SS |  |  | 2006-04-01 | 2006-12-30 | 274d | 1d |  | start no earlier than 2006-04-01 | Warman [5%]; Teague [10%]; AD Manager [5%] | 414.4h |  |
| 320 | 2.6.4 | **C4 Atmospheres** |  | 106d? | 2006-05-28 | 2006-09-10 |  |  |  |  |  |  | 112d |  |  |  | 114h |  |
| 321 | 2.6.4.1 | Acquire L2 from GDAAC |  | 95d | 2006-05-28 | 2006-08-30 |  |  |  | 2006-05-28 | 2006-08-30 | 95d | 123d |  | start no earlier than 2006-05-28 | Shiles [5%] | 38h |  |
| 322 | 2.6.4.2 | Archive L2 in LAADS |  | 95d? | 2006-06-01 | 2006-09-03 |  |  |  | 2006-06-01 | 2006-09-03 | 95d? | 119d |  | start no earlier than 2006-06-01 | Warman [5%]; AD Manager [5%] | 76h |  |
| 323 | 2.6.4.3 | GDAAC Stop C4 Dist | milestone | 1d? | 2006-09-10 | 2006-09-10 |  |  |  |  |  |  | 112d |  | start no earlier than 2006-09-10 |  |  |  |
| 324 | 2.7 | **Golden Months** |  | 317d? | 2006-02-16 | 2006-12-29 |  |  |  | 2006-02-16 | 2006-09-30 | 227d? | 2d |  |  |  | 176.4h |  |
| 325 | 2.7.1 | **Atmospheres** |  | 198d? | 2006-06-15 | 2006-12-29 |  |  |  | 2006-06-15 | 2006-09-30 | 108d? | 2d |  |  |  | 176.4h |  |
| 326 | 2.7.1.1 | Acquire GDAAC data (6.4.3.1.1) |  | 30d | 2006-06-15 | 2006-07-14 |  |  |  | 2006-06-15 | 2006-07-14 | 30d | 170d |  | start no earlier than 2006-06-15 | Ingest Tech [5%] | 12h |  |
| 327 | 2.7.1.2 | Generate L1B metadata (6.4.3.1.2) |  | 30d | 2006-07-01 | 2006-07-30 |  |  |  | 2006-07-01 | 2006-07-30 | 30d | 154d |  | start no earlier than 2006-07-01 | DeShong [10%] | 24h |  |
| 328 | 2.7.1.3 | Ingest metadata LAADS (6.4.3.1.3) |  | 30d | 2006-07-01 | 2006-07-30 |  |  |  | 2006-07-01 | 2006-07-30 | 30d | 2d | 0d | start no earlier than 2006-07-01 | Warman [5%] | 12h |  |
| 329 | 2.7.1.4 | LAADS Test (4.4) |  | 11d | 2006-07-31 | 2006-08-10 | 328 |  |  | 2006-07-31 | 2006-08-10 | 11d | 2d | 0d |  | Ridgway [5%]; Warman [10%] | 13.2h |  |
| 330 | 2.7.1.5 | ITRR (1.1.4.8) |  | 3d | 2006-08-11 | 2006-08-13 | 329 |  |  | 2006-08-11 | 2006-08-13 | 3d | 2d | 0d |  | Teague [20%] | 4.8h |  |
| 331 | 2.7.1.6 | MODAPS dist (6.4.3.1.4) |  | 138d | 2006-08-14 | 2006-12-29 | 330 |  |  | 2006-08-14 | 2006-12-29 | 138d | 2d | 0d |  | Warman [5%] | 55.2h |  |
| 332 | 2.7.1.7 | MODAPS POD (6.4.3.1.5) |  | 138d | 2006-08-14 | 2006-12-29 | 331SS |  |  | 2006-08-14 | 2006-12-29 | 138d | 2d |  |  | Warman [5%] | 55.2h |  |
| 333 | 2.7.1.8 | GDAAC Stop dist | milestone | 1d? | 2006-08-14 | 2006-08-14 |  |  |  | 2006-08-14 | 2006-08-14 | 1d? | 139d |  | start no earlier than 2006-08-14 |  |  |  |
| 334 | 2.7.2 | Land (6.4.3.2) |  | 1d? | 2006-02-16 | 2006-02-16 |  |  |  | 2006-02-16 | 2006-02-16 | 1d? | 318d |  |  |  |  |  |

| ID | WBS | Task | Type | Duration | Start | Finish | Predecessors | Complete | Remaining | Baseline start | Baseline finish | Baseline duration | Total slack | Free slack | Constraint | Resources | Work | Actual work |
| --- | --- | --- | --- | --- | --- | --- | --- | --- | --- | --- | --- | --- | --- | --- | --- | --- | --- | --- |
| 335 | 2.8 | **EDOS Interface** |  | 201d? | 2006-02-01 A | 2006-08-20 |  | 30% | 140.85d? | 2006-02-01 | 2006-09-30 | 242d? | 133d |  |  |  | 313.71h | 62.8h |
| 336 | 2.8.1 | EDOS Meetings (3.3.1) |  | 119d | 2006-02-01 A | 2006-05-30 |  | 50% | 59.5d | 2006-02-01 | 2006-05-30 | 119d | 215d |  | start no earlier than 2006-02-01 | Ye [5%] | 47.6h | 23.8h |
| 337 | 2.8.2 | Develop Interface (3.3.2) |  | 78d | 2006-03-15 A | 2006-05-31 |  | 25% | 58.5d | 2006-05-01 | 2006-05-31 | 31d | 214d |  | start no earlier than 2006-03-15 | Ye [15%]; Shi [10%] | 156h | 39h |
| 338 | 2.8.3 | EDOS Connect to PDR | milestone | 1d? | 2006-04-30 | 2006-04-30 |  |  |  |  |  |  | 245d |  | start no earlier than 2006-04-30 |  |  |  |
| 339 | 2.8.4 | **ETE Testing (4.5.1)** |  | 60d | 2006-06-01 | 2006-07-30 |  |  |  | 2006-06-01 | 2006-07-30 | 60d | 150d |  |  |  | 105.31h |  |
| 340 | 2.8.4.1 | Terra |  | 30d | 2006-06-01 | 2006-06-30 | 253SS |  |  | 2006-06-01 | 2006-06-30 | 30d | 92d | 0d | start no earlier than 2006-06-01 | DeShong [10%]; Ingest Tech [10%]; Ye [10%] | 52.57h |  |
| 341 | 2.8.4.2 | Aqua |  | 30d | 2006-07-01 | 2006-07-30 | 340 |  |  | 2006-07-01 | 2006-07-30 | 30d | 92d | 0d |  | DeShong [10%]; Ingest Tech [10%]; Ye [10%] | 52.74h |  |
| 342 | 2.8.5 | ITRR (1.1.4.9) |  | 3d | 2006-07-31 | 2006-08-02 | 341 |  |  | 2006-07-31 | 2006-08-02 | 3d | 92d | 0d |  | Teague [20%] | 4.8h |  |
| 343 | 2.8.6 | Hire L0 Ingest Tech | milestone | 1d? | 2006-03-16 | 2006-03-16 |  |  |  | 2006-03-16 | 2006-03-16 | 1d? | 290d |  | start no earlier than 2006-03-16 |  |  |  |
| 344 | 2.8.7 | MODAPS Operational (6.3.4.2) | milestone | 1d | 2006-08-03 | 2006-08-03 | 342 |  |  | 2006-08-03 | 2006-09-30 | 59d | 150d |  | finish no earlier than 2006-08-03 |  |  |  |
| 345 | 2.8.8 | Stop EDOS to GDAAC | milestone | 1d? | 2006-08-20 | 2006-08-20 |  |  |  | 2006-08-20 | 2006-08-20 | 1d? | 133d |  | start no earlier than 2006-08-20 |  |  |  |
| 346 | 2.9 | **L0 Distribution** |  | 364d | 2006-01-01 A | 2006-12-30 |  | 14% | 311.42d | 2006-05-01 | 2006-09-30 | 153d | 1d |  |  |  | 334.4h |  |
| 347 | 2.9.1 | Send All L0 to OCDPS |  | 104d | 2006-01-01 A | 2006-04-14 |  | 87% | 14d | 2006-01-01 | 2006-03-31 | 90d | 261d |  | start no earlier than 2006-01-01 |  |  |  |
| 348 | 2.9.2 | Send L0 Gaps to OCDPS |  | 268d | 2006-04-07 | 2006-12-30 |  |  |  | 2006-04-01 | 2006-12-30 | 274d | 1d |  | start no earlier than 2006-04-07 |  |  |  |
| 349 | 2.9.3 | Modify LAADS (3.4.1) |  | 60d | 2006-05-14 | 2006-07-12 |  |  |  | 2006-05-14 | 2006-07-12 | 60d | 6d | 5d | start no earlier than 2006-05-14 | Ye [5%]; Devine [10%]; Sinno [5%] | 96h |  |
| 350 | 2.9.4 | Dist Test (4.5.3) |  | 20d | 2006-06-23 | 2006-07-12 |  |  |  | 2006-06-23 | 2006-07-12 | 20d | 1d | 0d | start no earlier than 2006-06-23 | AD Manager [10%]; Warman [5%]; Sinno [5%] | 32h |  |
| 351 | 2.9.5 | ITRR (1.1.4.10) |  | 3d | 2006-07-13 | 2006-07-15 | 350 |  |  | 2006-07-13 | 2006-07-15 | 3d | 1d | 0d |  | Teague [20%] | 4.8h |  |
| 352 | 2.9.6 | MODAPS Operations (6.4.4.2) |  | 168d | 2006-07-16 | 2006-12-30 | 351 |  |  | 2006-07-16 | 2006-12-30 | 168d | 1d |  |  | AD Manager [5%]; Warman [5%]; Sinno [5%] | 201.6h |  |
| 353 | 2.10 | **ECHO** |  | 333d? | 2006-02-01 A | 2006-12-30 |  | 12% | 292.36d? | 2006-02-01 | 2006-09-30 | 242d | 1d |  |  |  | 1342.64h | 239.7h |
| 354 | 2.10.1 | ECHO Meetings (3.7.1) |  | 79d | 2006-02-01 A | 2006-04-20 |  | 75% | 19.75d | 2006-02-01 | 2006-04-20 | 79d | 255d |  | start no earlier than 2006-02-01 | Ye [5%] | 31.6h | 23.7h |
| 355 | 2.10.2 | Develop Metadata Interface (3.7.2) |  | 60d | 2006-03-15 A | 2006-05-13 |  | 30% | 42d | 2006-03-15 | 2006-05-13 | 60d | 6d | 1d | start no earlier than 2006-03-15 | Shi [70%]; Ye [30%]; Devine [50%] | 720h | 216h |
| 356 | 2.10.3 | Metadata Test (4.7.1) |  | 14d | 2006-04-14 | 2006-04-27 |  |  |  | 2006-04-14 | 2006-04-27 | 14d | 1d | 0d | finish no earlier than 2006-04-27 | AD Manager [10%]; Warman [10%]; Ye [5%] | 28h |  |
| 357 | 2.10.4 | ITRR (1.1.4.13) |  | 3d | 2006-04-28 | 2006-04-30 | 356 |  |  | 2006-04-28 | 2006-04-30 | 3d | 1d | 0d | finish no earlier than 2006-04-30 | Teague [20%] | 4.8h |  |
| 358 | 2.10.5 | Metadata export (6.3.5.1) |  | 244d | 2006-05-01 | 2006-12-30 | 357, 306SS-14d |  |  | 2006-05-01 | 2006-12-30 | 244d | 1d |  | start no earlier than 2006-05-01 | Warman [2%] | 39.04h |  |
| 359 | 2.10.6 | Reconciliation Test |  | 6d | 2006-05-09 | 2006-05-14 |  |  |  | 2006-05-09 | 2006-05-14 | 6d | 230d | 0d | start no earlier than 2006-05-09 | AD Manager [10%]; Warman [10%]; Ye [5%] | 12h |  |
| 360 | 2.10.7 | Start Reconciliation | milestone | 1d? | 2006-05-15 | 2006-05-15 | 355, 359 |  |  |  |  |  | 230d |  | start no earlier than 2006-05-15 |  |  |  |
| 361 | 2.10.8 | Develop Order Interface (3.7.2) |  | 60d | 2006-05-19 | 2006-07-17 | 355, 465FF |  |  | 2006-05-14 | 2006-07-12 | 60d | 1d | 0d | start no earlier than 2006-05-14 | Devine [20%]; Shi [40%]; Ye [10%] | 336h |  |
| 362 | 2.10.9 | Request ETE Test (4.7.2) |  | 30d | 2006-07-18 | 2006-08-16 | 361 |  |  | 2006-07-13 | 2006-08-11 | 30d | 1d | 0d |  | AD Manager [10%]; Warman [10%]; Ye [5%] | 60h |  |
| 363 | 2.10.10 | ITRR (1.1.4.13) |  | 3d | 2006-08-17 | 2006-08-19 | 362 |  |  | 2006-08-12 | 2006-08-14 | 3d | 1d | 0d |  | Teague [20%] | 4.8h |  |
| 364 | 2.10.11 | Request Processing (6.4.5.1) |  | 133d | 2006-08-20 | 2006-12-30 | 363 |  |  | 2006-08-15 | 2006-12-30 | 138d | 1d |  |  | Warman [10%] | 106.4h |  |

| ID | WBS | Task | Type | Duration | Start | Finish | Predecessors | Complete | Remaining | Baseline start | Baseline finish | Baseline duration | Total slack | Free slack | Constraint | Resources | Work | Actual work |
| --- | --- | --- | --- | --- | --- | --- | --- | --- | --- | --- | --- | --- | --- | --- | --- | --- | --- | --- |
| 365 | 2.11 | **Metrics** |  | 364d | 2006-01-01 A | 2006-12-30 |  | 25% | 273.93d | 2006-01-01 | 2006-09-30 | 273d | 1d |  |  |  | 540.64h | 168.06h |
| 366 | 2.11.1 | EMS Meetings (3.6.1) |  | 59d | 2006-01-01 A | 2006-02-28 A |  | 100% |  | 2006-01-01 | 2006-03-01 | 60d |  |  | start no earlier than 2006-01-01 | Horrocks [5%]; Teague [2%] | 33.04h | 33.04h |
| 367 | 2.11.2 | Establish Interface (3.6.2) |  | 85d | 2006-01-11 A | 2006-04-05 |  | 95% | 4.25d | 2006-01-11 | 2006-03-26 | 75d | 270d |  | start no earlier than 2006-01-11 | Horrocks [10%]; Teague [2%] | 81.6h | 77.52h |
| 368 | 2.11.3 | Establish LAADS Metrics (3.6.3) |  | 45d | 2006-02-01 A | 2006-03-17 A |  | 100% |  | 2006-02-01 | 2006-03-17 | 45d |  |  | start no earlier than 2006-02-01 | Horrocks [5%]; Teague [2%] | 25.2h | 25.2h |
| 369 | 2.11.4 | EMS Tests (4.6) |  | 85d | 2006-01-11 A | 2006-04-05 |  | 95% | 4.25d | 2006-01-11 | 2006-03-31 | 80d | 1d | 0d | start no earlier than 2006-01-11 | Horrocks [5%] | 34h | 32.3h |
| 370 | 2.11.5 | ITRR (1.1.4.12) |  | 4d | 2006-04-06 | 2006-04-09 | 369 |  |  | 2006-04-01 | 2006-04-03 | 3d | 1d | 0d |  | Teague [20%] | 6.4h |  |
| 371 | 2.11.6 | Generate EMS Metrics (1.8.1) |  | 265d | 2006-04-10 | 2006-12-30 | 370 |  |  | 2006-04-04 | 2006-12-30 | 271d | 1d |  |  | DeShong [2%] | 42.4h |  |
| 372 | 2.11.7 | Generate LAADS Metrics (1.8.2) |  | 265d | 2006-04-10 | 2006-12-30 | 370 |  |  | 2006-04-04 | 2006-12-30 | 271d | 1d |  | start no earlier than 2006-04-04 | Warman [5%] | 106h |  |
| 373 | 2.11.8 | Report Metrics (1.8.3) |  | 265d | 2006-04-10 | 2006-12-30 |  |  |  | 2006-04-04 | 2006-12-30 | 271d | 1d |  | start no earlier than 2006-04-10 | DeShong [5%]; AD Manager [5%] | 212h |  |
| 374 | 2.12 | **Support Functions** |  | 364d? | 2006-01-01 A | 2006-12-30 |  | 18% | 297.02d? | 2006-01-01 | 2006-09-30 | 273d? | 1d |  |  |  | 15802.2h | 2020.02h |
| 375 | 2.12.1 | **Schedules** |  | 364d | 2006-01-01 A | 2006-12-30 |  | 16% | 304.27d | 2006-01-01 | 2006-09-30 | 273d | 1d |  |  |  | 249.76h | 65.61h |
| 376 | 2.12.1.1 | Develop Atmospheres (1.2.1) |  | 64d | 2006-01-01 A | 2006-03-05 A |  | 100% |  | 2006-01-01 | 2006-02-28 | 59d |  |  | start no earlier than 2006-01-01 | Teague [10%] | 51.2h | 51.2h |
| 377 | 2.12.1.2 | Develop Land (1.2.2) |  | 244d | 2006-05-01 | 2006-12-30 |  |  |  | 2006-05-01 | 2006-12-30 | 244d | 1d |  | start no earlier than 2006-05-01 | Teague [5%] | 97.6h |  |
| 378 | 2.12.1.3 | Update (1.2.3) |  | 333d | 2006-02-01 A | 2006-12-30 |  | 19% | 269.73d | 2006-02-01 | 2006-12-30 | 333d | 1d |  | start no earlier than 2006-02-01 | Teague [2%] | 53.28h | 10.12h |
| 379 | 2.12.1.4 | Report Actuals (1.2.4) |  | 298d | 2006-03-08 A | 2006-12-30 |  | 9% | 271.18d | 2006-03-08 | 2006-12-30 | 298d | 1d |  | start no earlier than 2006-03-08 | Teague [2%] | 47.68h | 4.29h |
| 380 | 2.12.2 | **User Support** |  | 319d? | 2006-02-15 A | 2006-12-30 |  | 4% | 306.06d? | 2006-02-15 | 2006-09-30 | 228d | 1d |  |  |  | 4824.8h | 382.8h |
| 381 | 2.12.2.1 | Delivery Support (6.5.1.1) |  | 319d | 2006-02-15 A | 2006-12-30 |  | 15% | 271.15d | 2006-02-15 | 2006-12-30 | 319d | 1d |  | start no earlier than 2006-02-15 | User Support | 2552h | 382.8h |
| 382 | 2.12.2.2 | Hire Tier 1 Support | milestone | 1d? | 2006-03-16 | 2006-03-16 |  |  |  | 2006-03-16 | 2006-03-16 | 1d? | 290d |  | start no earlier than 2006-03-16 |  |  |  |
| 383 | 2.12.2.3 | Atmos Sci Support (6.5.1.2) |  | 270d | 2006-04-05 | 2006-12-30 |  |  |  | 2006-04-01 | 2006-12-30 | 274d | 1d |  | start no earlier than 2006-04-05 | Hucek [50%] | 1080h |  |
| 384 | 2.12.2.4 | Phase-over GDAAC support |  | 270d | 2006-04-05 | 2006-12-30 |  |  |  | 2006-04-01 | 2006-12-30 | 274d | 1d |  | start no earlier than 2006-04-05 | Teague [5%] | 108h |  |
| 385 | 2.12.2.5 | User Surveys (1.15) |  | 61d | 2006-07-01 | 2006-08-30 |  |  |  | 2006-07-01 | 2006-08-30 | 61d | 123d |  | start no earlier than 2006-07-01 | AD Manager [5%]; Teague [5%] | 48.8h |  |
| 386 | 2.12.2.6 | Land Science Support ST (6.5.2) |  | 259d | 2006-04-16 | 2006-12-30 |  |  |  | 2006-04-01 | 2006-12-30 | 274d | 1d |  | start no earlier than 2006-04-16 | Vogel [50%] | 1036h |  |
| 387 | 2.12.3 | **Quality Assurance** |  | 265d | 2006-04-10 | 2006-12-30 |  |  |  | 2006-04-01 | 2006-09-30 | 183d | 1d |  |  |  | 3980h |  |
| 388 | 2.12.3.1 | Ops QA atmos (6.6.1) |  | 265d | 2006-04-10 | 2006-12-30 |  |  |  | 2006-04-01 | 2006-12-30 | 274d | 1d |  | start no earlier than 2006-04-10 | Fireman [90%] | 1908h |  |
| 389 | 2.12.3.2 | Ops QA Land (6.6.2) |  | 259d | 2006-04-16 | 2006-12-30 |  |  |  | 2006-04-01 | 2006-12-30 | 274d | 1d |  | start no earlier than 2006-04-16 | LDOPE | 2072h |  |

| ID | WBS | Task | Duration | Start | Finish | Predecessors | Complete | Remaining | Baseline start | Baseline finish | Baseline duration | Total slack | Free slack | Constraint | Resources | Work | Actual work |
| --- | --- | --- | --- | --- | --- | --- | --- | --- | --- | --- | --- | --- | --- | --- | --- | --- | --- |
| 390 | 2.12.4 | **Configuration Control (1.5) (C-K)** | 364d | 2006-01-01 A | 2006-12-30 |  | 14% | 311.4d | 2006-01-01 | 2006-12-30 | 364d | 1d |  |  |  | 1400.4h | 218.16h |
| 391 | 2.12.4.1 | **CM (1.5.1)** | 364d | 2006-01-01 A | 2006-12-30 |  | 25% | 273.1d | 2006-01-01 | 2006-12-30 | 364d | 1d |  |  |  | 1294.4h | 218.16h |
| 392 | 2.12.4.1.1 | Staff 1 | 101d | 2006-01-01 A | 2006-04-11 |  | 90% | 10.1d | 2006-01-01 | 2006-03-31 | 90d | 1d | 0d | start no earlier than 2006-01-01 | Liang [30%] | 242.4h | 218.16h |
| 393 | 2.12.4.1.2 | Staff 2 | 263d | 2006-04-12 | 2006-12-30 | 392 |  |  | 2006-04-01 | 2006-12-30 | 274d | 1d |  |  | Christopher-Knight [50%] | 1052h |  |
| 394 | 2.12.4.2 | CCB (1.5.2) | 265d | 2006-04-10 | 2006-12-30 |  |  |  | 2006-04-10 | 2006-12-30 | 265d | 1d |  | start no earlier than 2006-04-10 | Teague [5%] | 106h |  |
| 395 | 2.12.5 | **Risk Management (1.6) (Teague)** | 265d | 2006-04-10 | 2006-12-30 |  |  |  | 2006-03-20 | 2006-12-30 | 286d | 1d |  |  |  | 233.2h |  |
| 396 | 2.12.5.1 | Risk Management Board (1.6.1) | 265d | 2006-04-10 | 2006-12-30 |  |  |  | 2006-04-10 | 2007-01-10 | 276d | 1d |  | start no earlier than 2006-04-10 | Teague [3%] | 63.6h |  |
| 397 | 2.12.5.2 | Mitigation Plans (1.6.2) | 265d | 2006-04-10 | 2006-12-30 |  |  |  | 2006-04-10 | 2007-01-10 | 276d | 1d |  | start no earlier than 2006-04-10 | Teague [3%]; Sinno [5%] | 169.6h |  |
| 398 | 2.12.6 | **Problem Tracking (1.7) (Woreta)** | 364d | 2006-01-01 A | 2006-12-30 |  | 25% | 271.45d | 2006-01-01 | 2006-09-30 | 273d | 1d |  |  |  | 364.4h | 82.09h |
| 399 | 2.12.6.1 | Establish Bugzilla (1.7.1) | 59d | 2006-01-01 A | 2006-02-28 A |  | 100% |  | 2006-01-01 | 2006-02-28 | 59d |  |  | start no earlier than 2006-01-01 | Woreta [10%] | 47.2h | 47.2h |
| 400 | 2.12.6.2 | Utilize Bugzilla (1.7.2) | 305d | 2006-03-01 A | 2006-12-30 | 399 | 11% | 271.45d | 2006-03-01 | 2006-12-30 | 305d | 1d |  |  | AD Manager [3%]; DeShong [3%]; Teague [7%] | 317.2h | 34.89h |
| 401 | 2.12.7 | **Admin** | 364d | 2006-01-01 A | 2006-12-30 |  | 26% | 269.36d | 2006-01-01 | 2006-11-01 | 305d | 1d |  |  |  | 728h | 189.28h |
| 402 | 2.12.7.1 | Property Management (1.12) | 364d | 2006-01-01 A | 2006-12-30 |  | 26% | 269.36d | 2006-01-01 | 2006-12-30 | 364d | 1d |  | start no earlier than 2006-01-01 | Parquet [10%] | 291.2h | 75.71h |
| 403 | 2.12.7.2 | Travel Support (1.13) | 364d | 2006-01-01 A | 2006-12-30 |  | 26% | 269.36d | 2006-01-01 | 2006-12-30 | 364d | 1d |  | start no earlier than 2006-01-01 | SAIC [5%] | 145.6h | 37.86h |
| 404 | 2.12.7.3 | Facilities Management (1.14) | 364d | 2006-01-01 A | 2006-12-30 |  | 26% | 269.36d | 2006-01-01 | 2006-12-30 | 364d | 1d |  | start no earlier than 2006-01-01 | Parquet [10%] | 291.2h | 75.71h |
| 405 | 2.12.8 | **Systems Engineering** | 364d? | 2006-01-01 A | 2006-12-30 |  | 35% | 235.78d? | 2006-01-01 | 2006-09-30 | 273d | 1d |  |  |  | 4021.66h | 1082.07h |
| 406 | 2.12.8.1 | Systems Administration (5.2) | 364d | 2006-01-01 A | 2006-12-30 |  | 26% | 269.36d | 2006-01-01 | 2006-12-30 | 364d | 1d |  | start no earlier than 2006-01-01 | Sinno [58%] | 1688.96h | 439.13h |
| 407 | 2.12.8.2 | Database Administration (5.3) | 364d | 2006-01-01 A | 2006-12-30 |  | 26% | 269.36d | 2006-01-01 | 2006-12-30 | 364d | 1d |  | start no earlier than 2006-01-01 | Woreta [45%] | 1310.4h | 340.7h |
| 408 | 2.12.8.3 | Systems Monitor (5.4) | 364d | 2006-01-01 A | 2006-12-30 |  | 26% | 269.36d | 2006-01-01 | 2006-12-30 | 364d | 1d |  | start no earlier than 2006-01-01 | Woreta [5%] | 145.6h | 37.86h |
| 409 | 2.12.8.4 | COTS (5.5) | 90d | 2006-01-01 A | 2006-03-31 A |  | 100% |  | 2006-01-01 | 2006-03-31 | 90d |  |  | start no earlier than 2006-01-01 | Sinno [5%] | 36h | 36h |
| 410 | 2.12.8.5 | MODAPS Maintenance (3.9) | 364d | 2006-01-01 A | 2006-12-30 |  | 26% | 269.36d | 2006-01-01 | 2006-12-30 | 364d | 1d |  | start no earlier than 2006-01-01 | Ye [10%]; Devine [10%]; Sinno [5%] | 704.7h | 165.98h |
| 411 | 2.12.8.6 | **Requirements Definition** | 65d | 2006-01-11 A | 2006-03-16 A |  | 100% |  | 2006-01-11 | 2006-03-16 | 65d |  |  |  |  | 44h | 44h |
| 412 | 2.12.8.6.1 | Software System (2.2.2) | 60d | 2006-01-11 A | 2006-03-11 A |  | 100% |  | 2006-01-11 | 2006-03-11 | 60d |  |  | start no earlier than 2006-01-11 | Sinno [5%] | 24h | 24h |
| 413 | 2.12.8.6.2 | **Hardware** | 65d | 2006-01-11 A | 2006-03-16 A |  | 100% |  | 2006-01-11 | 2006-03-16 | 65d |  |  |  |  | 20h | 20h |
| 414 | 2.12.8.6.2.1 | Atmospheres (2.2.3.1) | 20d | 2006-01-11 A | 2006-01-30 A |  | 100% |  | 2006-01-11 | 2006-01-30 | 20d |  |  | start no earlier than 2006-01-11 | Sinno [5%] | 8h | 8h |
| 415 | 2.12.8.6.2.2 | Land (2.2.3.2) | 30d | 2006-02-15 A | 2006-03-16 A |  | 100% |  | 2006-02-15 | 2006-03-16 | 30d |  |  | start no earlier than 2006-02-15 | Sinno [5%] | 12h | 12h |

| ID | WBS | Task | Type | Duration | Start | Finish | Predecessors | Complete | Remaining | Baseline start | Baseline finish | Baseline duration | Total slack | Free slack | Constraint | Resources | Work | Actual work |
| --- | --- | --- | --- | --- | --- | --- | --- | --- | --- | --- | --- | --- | --- | --- | --- | --- | --- | --- |
| 416 | 2.12.8.7 | **Systems Design** |  | 64d | 2006-02-01 A | 2006-04-05 |  | 96% | 2.67d | 2006-02-01 | 2006-04-05 | 64d | 270d |  |  |  | 19.2h | 18.4h |
| 417 | 2.12.8.7.1 | Atmospheres (2.3.1) |  | 28d | 2006-02-01 A | 2006-02-28 A |  | 100% |  | 2006-02-01 | 2006-02-28 | 28d |  |  | start no earlier than 2006-02-01 | Sinno [5%] | 11.2h | 11.2h |
| 418 | 2.12.8.7.2 | Land (2.3.2) |  | 20d | 2006-03-17 A | 2006-04-05 | 415 | 90% | 2d | 2006-03-17 | 2006-04-05 | 20d | 270d |  | start no earlier than 2006-03-17 | Sinno [5%] | 8h | 7.2h |
| 419 | 2.12.8.8 | **Hardware Deployment** |  | 91d? | 2006-04-01 | 2006-06-30 |  |  |  | 2006-03-15 | 2006-06-30 | 108d | 184d |  |  |  | 72.8h |  |
| 420 | 2.12.8.8.1 | New Power | milestone | 1d? | 2006-04-01 | 2006-04-01 |  |  |  | 2006-03-14 | 2006-03-14 | 1d? | 267d | 0d | start no earlier than 2006-04-01 |  |  |  |
| 421 | 2.12.8.8.2 | Atmospheres (2.4.1) |  | 7d | 2006-04-02 | 2006-04-08 | 420 |  |  | 2006-03-15 | 2006-03-21 | 7d | 267d |  | start no earlier than 2006-03-15 | Sinno [20%] | 11.2h |  |
| 422 | 2.12.8.8.3 | **Land (2.4.2)** |  | 61d | 2006-05-01 | 2006-06-30 |  |  |  | 2006-05-01 | 2006-06-30 | 61d | 184d |  |  |  | 61.6h |  |
| 423 | 2.12.8.8.3.1 | Acquire Hardware |  | 45d | 2006-05-01 | 2006-06-14 |  |  |  | 2006-05-01 | 2006-06-14 | 45d | 184d | 0d | start no earlier than 2006-05-01 | Sinno [10%] | 36h |  |
| 424 | 2.12.8.8.3.2 | Deploy Hardware |  | 16d | 2006-06-15 | 2006-06-30 | 423 |  |  | 2006-06-15 | 2006-06-30 | 16d | 184d |  |  | Sinno [20%] | 25.6h |  |
| 425 | 2.13 | **Documentation** |  | 350d | 2006-01-15 A | 2006-12-30 |  | 25% | 263.72d | 2006-01-15 | 2006-09-30 | 259d | 1d |  |  |  | 4817.52h | 1180.84h |
| 426 | 2.13.1 | **Production Website** |  | 318d | 2006-02-16 A | 2006-12-30 |  | 15% | 269d | 2006-02-16 | 2006-09-30 | 227d | 1d |  |  |  | 332.8h | 117.6h |
| 427 | 2.13.1.1 | Develop (3.8.1) |  | 49d | 2006-02-16 A | 2006-04-05 A |  | 100% |  | 2006-02-16 | 2006-03-30 | 43d |  |  |  | Horrocks [20%]; DeShong [10%] | 117.6h | 117.6h |
| 428 | 2.13.1.2 | Maintain (6.3.8) |  | 269d | 2006-04-06 | 2006-12-30 | 427 |  |  | 2006-03-31 | 2006-12-30 | 275d | 1d |  |  | Warman [5%]; Shiles [5%] | 215.2h |  |
| 429 | 2.13.2 | **Ops Website** |  | 318d | 2006-02-16 A | 2006-12-30 |  | 11% | 281.52d |  |  |  | 1d |  |  |  | 61.92h | 4.8h |
| 430 | 2.13.2.1 | Enhance |  | 152d | 2006-04-01 A | 2006-08-30 |  | 2% | 148.96d | 2006-04-01 | 2006-08-30 | 152d | 123d |  | start no earlier than 2006-04-01 | Horrocks [3%] | 36.48h | 0.73h |
| 431 | 2.13.2.2 | Maintain |  | 318d | 2006-02-16 A | 2006-12-30 |  | 16% | 267.12d | 2006-02-16 | 2006-12-30 | 318d | 1d |  |  | Horrocks [1%] | 25.44h | 4.07h |
| 432 | 2.13.3 | **LAADS Doc** |  | 166d | 2006-01-15 A | 2006-06-29 |  | 63% | 61.86d | 2006-01-15 | 2006-03-31 | 76d | 185d |  |  |  | 214h | 124.8h |
| 433 | 2.13.3.1 | Upgrade Atmos (1.3.1.1) |  | 75d | 2006-01-15 A | 2006-03-30 A |  | 100% |  | 2006-01-15 | 2006-03-20 | 65d |  |  | start no earlier than 2006-01-15 | Ridgway [5%] | 30h | 30h |
| 434 | 2.13.3.2 | Upgrade Land (1.3.1.2) |  | 79d | 2006-02-01 A | 2006-04-20 |  | 75% | 19.75d | 2006-02-01 | 2006-03-31 | 59d | 255d |  | start no earlier than 2006-02-01 | Vogel [20%] | 126.4h | 94.8h |
| 435 | 2.13.3.3 | LAADS Tutorial (1.3.1.2) |  | 60d | 2006-05-01 | 2006-06-29 | 465FF-45d |  |  | 2006-05-01 | 2006-06-29 | 60d | 185d |  | start no earlier than 2006-05-01 | Teague [2%]; Horrocks [10%] | 57.6h |  |
| 436 | 2.13.4 | MODAPS Documentation (1.3.1.4) |  | 274d | 2006-04-01 A | 2006-12-30 |  | 2% | 268.52d | 2006-04-01 | 2006-12-30 | 274d | 1d |  | start no earlier than 2006-04-01 | Ye [5%]; Devine [5%] | 219.2h | 4.38h |
| 437 | 2.13.5 | Test Plans (1.9) |  | 65d | 2006-02-01 A | 2006-04-06 |  | 90% | 6.5d | 2006-02-01 | 2006-03-31 | 59d | 269d |  | start no earlier than 2006-02-01 | AD Manager [5%]; Teague [20%] | 130h | 117h |
| 438 | 2.13.6 | **Ops Procedures** |  | 179d | 2006-02-15 A | 2006-08-12 |  | 24% | 136.81d | 2006-02-15 | 2006-08-12 | 179d | 141d |  |  |  | 626.4h | 199.44h |
| 439 | 2.13.6.1 | Develop for A/D (1.4.1) |  | 48d | 2006-02-15 A | 2006-04-03 A |  | 100% |  | 2006-02-15 | 2006-03-31 | 45d |  |  | start no earlier than 2006-02-15 | AD Manager [20%]; Teague [20%] | 153.6h | 153.6h |
| 440 | 2.13.6.2 | Develop for EDOS Ingest (1.4.2) |  | 122d | 2006-04-01 A | 2006-07-31 |  | 5% | 115.9d | 2006-04-01 | 2006-07-31 | 122d | 153d |  | start no earlier than 2006-04-01 | DeShong [5%]; Teague [5%]; Ingest Tech [20%] | 292.8h | 14.64h |
| 441 | 2.13.6.3 | Develop for ECHO metadata (1.4.3) |  | 30d | 2006-04-01 A | 2006-04-30 |  | 10% | 27d | 2006-04-01 | 2006-04-30 | 30d | 245d |  | start no earlier than 2006-04-01 | AD Manager [5%]; Teague [5%] | 24h | 2.4h |
| 442 | 2.13.6.4 | Develop for ECHO requests (1.4.4) |  | 30d | 2006-04-01 A | 2006-04-30 |  | 10% | 27d | 2006-04-01 | 2006-04-30 | 30d | 245d |  | start no earlier than 2006-04-01 | AD Manager [5%]; Teague [5%] | 24h | 2.4h |
| 443 | 2.13.6.5 | Document Procedures (1.3.2) |  | 165d | 2006-03-01 A | 2006-08-12 |  | 20% | 132d | 2006-03-01 | 2006-08-12 | 165d | 141d |  | start no earlier than 2006-03-01 | AD Manager [5%]; DeShong [5%] | 132h | 26.4h |

| ID | WBS | Task | Type | Duration | Start | Finish | Predecessors | Complete | Remaining | Baseline start | Baseline finish | Baseline duration | Total slack | Free slack | Constraint | Resources | Work | Actual work |
| --- | --- | --- | --- | --- | --- | --- | --- | --- | --- | --- | --- | --- | --- | --- | --- | --- | --- | --- |
| 444 | 2.13.7 | **Transition Doc** |  | 88d | 2006-02-01 A | 2006-04-29 |  | 69% | 27.46d | 2006-02-01 | 2006-04-29 | 88d | 246d |  |  |  | 121.2h | 88.02h |
| 445 | 2.13.7.1 | GDAAC/MODAPS Develop (1.3.4.1) |  | 85d | 2006-02-01 A | 2006-04-26 |  | 75% | 21.25d | 2006-02-01 | 2006-04-26 | 85d | 249d |  | start no earlier than 2006-02-01 | Teague [5%]; DeShong [5%]; AD Manager [5%] | 102h | 76.5h |
| 446 | 2.13.7.2 | Deploy (1.3.4.2) |  | 60d | 2006-03-01 A | 2006-04-29 |  | 60% | 24d | 2006-03-01 | 2006-04-29 | 60d | 246d |  | start no earlier than 2006-03-01 | DeShong [2%]; AD Manager [2%] | 19.2h | 11.52h |
| 447 | 2.13.8 | **ICD/OA** |  | 179d | 2006-02-01 A | 2006-07-29 |  | 17% | 148.81d |  |  |  | 155d |  |  |  | 3112h | 524.8h |
| 448 | 2.13.8.1 | GDAAC MOA (1.3.3.3) |  | 90d | 2006-04-01 | 2006-06-29 |  |  |  | 2006-04-01 | 2006-06-29 | 90d | 185d |  | start no earlier than 2006-04-01 | Broder | 720h |  |
| 449 | 2.13.8.2 | Generate ICD/OA (1.3.3.1) |  | 149d | 2006-02-01 A | 2006-06-29 |  | 40% | 89.4d | 2006-02-01 | 2006-06-29 | 149d | 185d |  | start no earlier than 2006-02-01 | Broder | 1192h | 476.8h |
| 450 | 2.13.8.3 | Generate ICD/OA |  | 120d | 2006-04-01 A | 2006-07-29 |  | 5% | 114d | 2006-04-01 | 2006-07-29 | 120d | 155d |  | start no earlier than 2006-04-01 | Broder | 960h | 48h |
| 451 | 2.13.8.4 | Generate ICD (1.3.3.4) |  | 30d | 2006-04-05 | 2006-05-04 |  |  |  | 2006-04-05 | 2006-05-04 | 30d | 241d |  | start no earlier than 2006-04-05 | Broder | 240h |  |
| 452 | 2.14 | **LAADS Releases** |  | 344d? | 2006-01-01 A | 2006-12-10 |  | 29% | 242.78d? | 2006-01-01 | 2006-12-10 | 344d? | 21d |  |  |  | 5677.2h | 1320.4h |
| 453 | 2.14.1 | **Version 3** |  | 95d? | 2006-01-01 A | 2006-04-05 |  | 99% | 1.37d? | 2006-01-01 | 2006-04-01 | 91d? | 270d |  |  |  | 1255.6h | 1253.44h |
| 454 | 2.14.1.1 | Requirements Def (2.2.1.1) |  | 15d | 2006-01-01 A | 2006-01-15 A |  | 100% |  | 2006-01-01 | 2006-01-15 | 15d |  |  | start no earlier than 2006-01-01 | Teague [5%] | 6h | 6h |
| 455 | 2.14.1.2 | Develop (3.2.1.1) |  | 77d | 2006-01-10 A | 2006-03-27 A |  | 100% |  | 2006-01-10 | 2006-03-15 | 65d |  |  | start no earlier than 2006-01-10 | Ye [10%]; Fu [20%]; Horrocks [70%]; Ederer [80%]; Sinno [5%] | 1139.6h | 1139.6h |
| 456 | 2.14.1.3 | Internal Tests (2.1.4.1) |  | 37d | 2006-02-14 A | 2006-03-22 A |  | 100% |  | 2006-02-14 | 2006-03-15 | 30d |  |  | start no earlier than 2006-02-14 | Ye [5%]; Horrocks [10%] | 44.4h | 44.4h |
| 457 | 2.14.1.4 | User Reviews (1.1.6.1) |  | 28d | 2006-02-23 A | 2006-03-22 A | 456FF | 100% |  | 2006-03-02 | 2006-03-15 | 14d |  |  | start no earlier than 2006-02-25 | Ridgway [5%]; Saleous [5%] | 22.4h | 22.4h |
| 458 | 2.14.1.5 | External Tests (4.3.1) |  | 36d | 2006-02-28 A | 2006-04-04 |  | 95% | 1.8d | 2006-03-16 | 2006-03-31 | 16d | 270d | 0d | start no earlier than 2006-02-28 | AD Manager [10%]; Sinno [5%] | 43.2h | 41.04h |
| 459 | 2.14.1.6 | Deploy (3.2.1.2) | milestone | 1d? | 2006-04-05 | 2006-04-05 | 458, 279SS |  |  | 2006-04-01 | 2006-04-01 | 1d? | 270d |  | start no earlier than 2006-04-01 |  |  |  |
| 460 | 2.14.2 | **Client Server** |  | 74d? | 2006-02-01 | 2006-04-15 |  |  |  |  |  |  | 260d |  |  |  |  |  |
| 461 | 2.14.2.1 | McIDAS | milestone | 1d? | 2006-02-01 | 2006-02-01 |  |  |  |  |  |  | 333d |  | start no earlier than 2006-02-01 |  |  |  |
| 462 | 2.14.2.2 | OpenDAP | milestone | 1d? | 2006-04-15 | 2006-04-15 |  |  |  |  |  |  | 260d |  | start no earlier than 2006-04-15 |  |  |  |
| 463 | 2.14.3 | **Version 4** |  | 199d? | 2006-02-01 A | 2006-08-18 |  | 13% | 173.14d? | 2006-02-01 | 2006-08-13 | 194d? | 135d |  |  |  | 1473.6h | 66.96h |
| 464 | 2.14.3.1 | Requirements Def (2.2.1.2) |  | 33d | 2006-02-01 A | 2006-03-05 A |  | 100% |  | 2006-02-01 | 2006-03-15 | 43d |  |  | start no earlier than 2006-02-01 | Teague [5%] | 13.2h | 13.2h |
| 465 | 2.14.3.2 | Develop (3.2.1.2) |  | 112d | 2006-03-28 A | 2006-07-17 | 464, 455, 349FF | 5% | 106.4d | 2006-03-16 | 2006-07-12 | 119d | 1d | 0d | start no earlier than 2006-03-12 | Fu [10%]; Ederer [20%]; Devine [15%]; Sinno [5%]; Horrocks [50%]; Ye [20%] | 1075.2h | 53.76h |
| 466 | 2.14.3.3 | Internal Tests (2.1.4.2) |  | 90d | 2006-04-14 | 2006-07-12 |  |  |  | 2006-04-14 | 2006-07-12 | 90d | 140d | 0d | start no earlier than 2006-04-14 | Horrocks [10%]; Devine [15%]; Ye [20%] | 324h |  |
| 467 | 2.14.3.4 | User Reviews (1.1.6.2) |  | 30d | 2006-06-13 | 2006-07-12 | 466FF |  |  | 2006-06-13 | 2006-07-12 | 30d | 140d | 5d | start no earlier than 2006-06-13 | Saleous [5%]; Ridgway [5%] | 24h |  |
| 468 | 2.14.3.5 | External Tests (4.3.2) |  | 31d | 2006-07-18 | 2006-08-17 | 467, 465, 362FF |  |  | 2006-07-13 | 2006-08-12 | 31d | 135d | 0d | start no earlier than 2006-07-12 | AD Manager [10%]; Sinno [5%] | 37.2h |  |
| 469 | 2.14.3.6 | Deploy (3.2.2.2) | milestone | 1d? | 2006-08-18 | 2006-08-18 | 468 |  |  | 2006-08-13 | 2006-08-13 | 1d? | 135d |  | start no earlier than 2006-08-13 |  |  |  |

| ID | WBS | Task | Type | Duration | Start | Finish | Predecessors | Baseline start | Baseline finish | Baseline duration | Total slack | Free slack | Constraint | Resources | Work |
| --- | --- | --- | --- | --- | --- | --- | --- | --- | --- | --- | --- | --- | --- | --- | --- |
| 470 | 2.14.4 | **Version 5** |  | 224d? | 2006-05-01 | 2006-12-10 |  | 2006-05-01 | 2006-12-10 | 224d? | 21d |  |  |  | 2948h |
| 471 | 2.14.4.1 | Requirements Def (2.2.1.3) |  | 75d | 2006-05-01 | 2006-07-14 |  | 2006-05-01 | 2006-06-29 | 60d | 170d |  | start no earlier than 2006-05-01 | Teague [5%] | 30h |
| 472 | 2.14.4.2 | Develop (3.2.1.3) |  | 120d | 2006-07-18 | 2006-11-14 | 465 | 2006-07-13 | 2006-11-09 | 120d | 47d |  | start no earlier than 2006-05-21 | Fu [40%]; Ederer [20%]; Horrocks [70%]; Sinno [5%]; Devine [50%]; Shi [30%]; Ye [60%] | 2640h |
| 473 | 2.14.4.3 | Internal Tests (2.1.4.3) |  | 45d | 2006-10-10 | 2006-11-23 |  | 2006-10-10 | 2006-11-23 | 45d | 21d | 0d | start no earlier than 2006-10-10 | Horrocks [20%]; Devine [20%]; Ye [25%] | 234h |
| 474 | 2.14.4.4 | User Reviews (1.1.6.3) |  | 31d | 2006-10-24 | 2006-11-23 | 473FF | 2006-10-24 | 2006-11-23 | 31d | 21d | 0d | start no earlier than 2006-10-24 | Saleous [5%]; Ridgway [5%] | 24.8h |
| 475 | 2.14.4.5 | External Tests (4.3.3) |  | 16d | 2006-11-24 | 2006-12-09 | 474 | 2006-11-24 | 2006-12-09 | 16d | 21d | 0d |  | AD Manager [10%]; Sinno [5%] | 19.2h |
| 476 | 2.14.4.6 | Deploy (3.2.3.2) | milestone | 1d? | 2006-12-10 | 2006-12-10 | 475 | 2006-12-10 | 2006-12-10 | 1d? | 21d |  |  |  |  |
